# JOHN DOE PROJECT ADM-PDM VERSION

Schedule from Primavera P6, 2000-06-05 to 2001-04-05, data date 2000-06-05, costs in USD.

## Calendars

- DP00 - 1: Mon-Fri 08:00-12:00, 13:00-17:00; Sat-Sun off. Exceptions (off unless hours are given): 2000-07-04, 2000-09-04, 2000-11-23, 2000-12-25, 2001-01-01.

## Resources

| Resource | Group |
| --- | --- |
| COST | labor |
| OP | labor |
| SV | labor |
| Plumbers | labor |
| Carpenters | labor |
| LB | labor |
| Electricians | labor |
| BM | labor |
| Iron Workers | labor |
| Roofers | labor |
| PF | labor |
| ST | labor |
| SM | labor |
| PA | labor |
| IN | labor |
| TL | labor |
| MA | labor |
| GZ | labor |

## Schedule

| ID | Activity | Duration | Start | Finish | Predecessors | Total float | Free float | Resources | Cost |
| --- | --- | --- | --- | --- | --- | --- | --- | --- | --- |
| 0 | START OF NETWORK | 1d | 2000-06-05 | 2000-06-05 |  | 0d |  |  |  |
| 0 1 | CLEAR SITE | 3d | 2000-06-06 | 2000-06-08 | 0 | 0d |  | COST; OP [120 h] | 28,000 |
| 0 210 | SUBMIT FOUNDATION REBAR | 10d | 2000-06-06 | 2000-06-19 | 0 | 20d | 0d |  |  |
| 0 212 | SUBMIT STRUCTURAL STEEL | 20d | 2000-06-06 | 2000-07-03 | 0 | 38d | 0d |  |  |
| 0 214 | SUBMIT CRANE | 20d | 2000-06-06 | 2000-07-03 | 0 | 23d | 0d |  |  |
| 0 216 | SUBMIT BAR JOISTS | 20d | 2000-06-06 | 2000-07-03 | 0 | 48d | 0d |  |  |
| 0 218 | SUBMIT SIDING | 20d | 2000-06-06 | 2000-07-03 | 0 | 44d | 0d |  |  |
| 0 220 | SUBMIT PLANT ELECTRICAL LOAD CENTER | 20d | 2000-06-06 | 2000-07-03 | 0 | 4d | 0d |  |  |
| 0 222 | SUBMIT POWER PANELS - PLANT | 20d | 2000-06-06 | 2000-07-03 | 0 | 31d | 0d |  |  |
| 0 224 | SUBMIT EXTERIOR DOORS | 20d | 2000-06-06 | 2000-07-03 | 0 | 37d | 0d |  |  |
| 0 225 | SUBMIT PLANT ELECTRICAL FIXTURES | 30d | 2000-06-06 | 2000-07-18 | 0 | 37d | 0d |  |  |
| 0 227 | SUBMIT PLANT HEATING AND VENTILATING FANS | 20d | 2000-06-06 | 2000-07-03 | 0 | 42d | 0d |  |  |
| 0 229 | SUBMIT BOILER | 20d | 2000-06-06 | 2000-07-03 | 0 | 77d | 0d |  |  |
| 0 231 | SUBMIT OIL TANK | 20d | 2000-06-06 | 2000-07-03 | 0 | 114d | 0d |  |  |
| 0 233 | SUBMIT PRECAST | 40d | 2000-06-06 | 2000-08-01 | 0 | 48d | 0d |  |  |
| 0 235 | SUBMIT PACKAGED A/C | 30d | 2000-06-06 | 2000-07-18 | 0 | 8d | 0d |  |  |
| 1 2 | SURVEY AND LAYOUT | 2d | 2000-06-09 | 2000-06-12 | 0 1 | 0d |  | COST; SV [48 h] | 2,500 |
| 2 3 | ROUGH GRADE | 2d | 2000-06-13 | 2000-06-14 | 1 2 | 0d |  | COST; OP [48 h] | 10,000 |
| 3 4 | DRILL WELL | 15d | 2000-06-15 | 2000-07-06 | 2 3 | 0d |  | COST; Plumbers [240 h] | 10,000 |
| 3 6 | WATER TANK FOUNDATIONS | 4d | 2000-06-15 | 2000-06-20 | 2 3 | 1d | 0d | COST; Carpenters [128 h]; LB [64 h] | 5,000 |
| 3 9 | EXCAVATE FOR SEWER | 10d | 2000-06-15 | 2000-06-28 | 2 3 | 4d | 0d | COST; OP [400 h] | 21,500 |
| 3 10 | EXCAVATE ELECTRIC MANHOLES | 1d | 2000-06-15 | 2000-06-15 | 2 3 | 13d | 0d | COST; OP [16 h] | 1,000 |
| 3 12 | OVERHEAD POLE LINE | 6d | 2000-06-15 | 2000-06-22 | 2 3 | 16d | 12d | COST; Electricians [192 h] | 30,000 |
| 10 11 | INSTALL ELECTRICAL MANHOLES | 5d | 2000-06-16 | 2000-06-22 | 3 10 | 13d | 9d | COST; Carpenters [160 h]; LB [80 h] | 6,500 |
| 210 211 | APPROVE FOUNDATION REBAR | 10d | 2000-06-20 | 2000-07-03 | 0 210 | 20d | 0d |  |  |
| 6 7 | ERECT WATER TANK | 10d | 2000-06-21 | 2000-07-05 | 3 6 | 1d | 0d | COST; BM [640 h] | 225,000 |
| 9 11 | INSTALL SEWER AND BACKFILL | 5d | 2000-06-29 | 2000-07-06 | 3 9 | 4d | 0d | COST; Plumbers [240 h] | 65,000 |
| 211 16 | FAB/DEL FOUNDATION REBAR | 10d | 2000-07-05 | 2000-07-18 | 210 211 | 20d |  |  |  |
| 212 213 | APPROVE STRUCTURAL STEEL | 10d | 2000-07-05 | 2000-07-18 | 0 212 | 38d | 0d |  |  |
| 214 215 | APPROVE CRANE | 10d | 2000-07-05 | 2000-07-18 | 0 214 | 23d | 0d |  |  |
| 216 217 | APPROVE BAR JOISTS | 10d | 2000-07-05 | 2000-07-18 | 0 216 | 48d | 0d |  |  |
| 218 219 | APPROVE SIDING | 10d | 2000-07-05 | 2000-07-18 | 0 218 | 44d | 0d |  |  |
| 220 221 | APPROVE PLANT ELECTRICAL LOAD CENTER | 10d | 2000-07-05 | 2000-07-18 | 0 220 | 4d | 0d |  |  |
| 222 223 | APPROVE POWER PANELS - PLANT | 10d | 2000-07-05 | 2000-07-18 | 0 222 | 31d | 0d |  |  |
| 224 225 | APPROVE EXTERIOR DOORS | 10d | 2000-07-05 | 2000-07-18 | 0 224 | 37d | 0d |  |  |
| 227 228 | APPROVE PLANT HEATING AND VENTILATING FANS | 10d | 2000-07-05 | 2000-07-18 | 0 227 | 42d | 0d |  |  |
| 229 230 | APPROVE BOILER | 10d | 2000-07-05 | 2000-07-18 | 0 229 | 77d | 0d |  |  |
| 231 232 | APPROVE OIL TANK | 10d | 2000-07-05 | 2000-07-18 | 0 231 | 114d | 0d |  |  |
| 7 8 | TANK PIPING & VALVES | 10d | 2000-07-06 | 2000-07-19 | 6 7 | 1d |  | COST; BM [320 h] | 40,000 |
| 4 5 | INSTALL WELL PUMP | 2d | 2000-07-07 | 2000-07-10 | 3 4 | 0d |  | COST; Plumbers [32 h] | 11,250 |
| 11 12 | INSTALL ELECTRICAL DUCT BANK | 3d | 2000-07-07 | 2000-07-11 | 9 11, 10 11 | 4d | 0d | COST; Electricians [144 h] | 7,500 |
| 5 8 | UNDERGROUND WATER PIPING | 8d | 2000-07-11 | 2000-07-20 | 4 5 | 0d |  | COST; Plumbers [128 h] | 18,000 |
| 12 13 | PULL IN FEEDER | 5d | 2000-07-12 | 2000-07-18 | 3 12, 11 12 | 4d |  | COST; Electricians [160 h] | 6,000 |
| 213 23 | FAB/DEL STRUCTURAL STEEL | 40d | 2000-07-19 | 2000-09-13 | 212 213 | 38d | 0d | COST | 550,000 |
| 215 31 | FAB/DEL CRANE | 50d | 2000-07-19 | 2000-09-27 | 214 215 | 23d |  | COST | 180,000 |
| 217 33 | FAB/DEL BAR JOISTS | 30d | 2000-07-19 | 2000-08-29 | 216 217 | 48d |  | COST | 60,000 |
| 219 35 | FAB/DEL SIDING | 40d | 2000-07-19 | 2000-09-13 | 218 219 | 44d |  | COST | 300,000 |
| 221 300 | FAB/DEL PLANT ELECTRICAL LOAD CENTER | 90d | 2000-07-19 | 2000-11-22 | 220 221 | 4d |  |  |  |
| 223 301 | FAB/DEL POWER PANELS - PLANT | 75d | 2000-07-19 | 2000-11-01 | 222 223 | 31d | 19d |  |  |
| 225 226 | APPROVE PLANT ELECTRICAL FIXTURES | 15d | 2000-07-19 | 2000-08-08 | 0 225, 224 225 | 71d | 0d | COST | 60,000 |
| 225 302 | FAB/DEL EXTERIOR DOORS | 80d | 2000-07-19 | 2000-11-08 | 0 225, 224 225 | 37d | 14d |  |  |
| 228 304 | FAB/DEL PLANT HEATING AND VENTILATING FANS | 75d | 2000-07-19 | 2000-11-01 | 227 228 | 42d | 19d |  |  |
| 230 306 | FAB/DEL BOILER | 60d | 2000-07-19 | 2000-10-11 | 229 230 | 77d | 34d |  |  |
| 232 305 | FAB/DEL OIL TANK | 50d | 2000-07-19 | 2000-09-27 | 231 232 | 114d | 44d |  |  |
| 235 236 | APPROVE PACKAGED A/C | 10d | 2000-07-19 | 2000-08-01 | 0 235 | 8d | 0d |  |  |
| 8 13 | CONNECT WATER PIPING | 2d | 2000-07-21 | 2000-07-24 | 5 8, 7 8 | 0d |  | COST; BM [64 h] | 2,000 |
| 13 14 | BUILDING LAYOUT | 1d | 2000-07-25 | 2000-07-25 | 8 13, 12 13 | 0d |  | COST; SV [24 h] | 4,000 |
| 14 15 | DRIVE AND POUR PILES | 10d | 2000-07-26 | 2000-08-08 | 13 14 | 0d |  | COST; OP [160 h]; Carpenters [160 h]; LB [160 h] | 70,000 |
| 14 23 | EXCAVATE FOR OFFICE BUILDING | 3d | 2000-07-26 | 2000-07-28 | 13 14 | 70d | 32d | COST; OP [120 h] | 27,000 |
| 233 234 | APPROVE PRECAST | 10d | 2000-08-02 | 2000-08-15 | 0 233 | 48d | 0d |  |  |
| 236 60 | FAB/DEL PACKAGED A/C | 90d | 2000-08-02 | 2000-12-07 | 235 236 | 8d | 0d |  |  |
| 15 16 | EXCAVATE PLANT WAREHOUSE | 5d | 2000-08-09 | 2000-08-15 | 14 15 | 0d |  | COST; OP [200 h] | 86,000 |
| 226 51 | FAB/DEL PLANT ELECTRICAL FIXTURES | 75d | 2000-08-09 | 2000-11-22 | 225 226 | 71d | 46d |  |  |
| 16 17 | POUR PILE CAPS P-W | 5d | 2000-08-16 | 2000-08-22 | 15 16, 211 16 | 0d |  | COST; Carpenters [160 h]; LB [800 h] | 50,000 |
| 234 99 | FAB/DEL PRECAST | 30d | 2000-08-16 | 2000-09-27 | 233 234 | 48d | 10d | COST | 70,000 |
| 17 18 | FORM AND POUR GRADE BEAMS P-W | 10d | 2000-08-23 | 2000-09-06 | 16 17 | 0d |  | COST; Carpenters [160 h]; LB [160 h] | 70,000 |
| 18 19 | BACKFILL AND COMPACT P-W | 3d | 2000-09-07 | 2000-09-11 | 17 18 | 0d |  | COST; OP [120 h] | 9,000 |
| 18 21 | FORM AND POUR RAILROAD LOADING DOCK P-W | 5d | 2000-09-07 | 2000-09-13 | 17 18 | 8d | 0d | COST; Carpenters [160 h]; LB [80 h] | 15,000 |
| 18 22 | FORM AND POUR TRUCK LOADING DOCK P-W | 5d | 2000-09-07 | 2000-09-13 | 17 18 | 8d |  | COST; Carpenters [160 h]; LB [80 h] | 15,000 |
| 19 20 | UNDERSLAB PLUMBING P-W | 5d | 2000-09-12 | 2000-09-18 | 18 19 | 0d |  | COST; Plumbers [160 h] | 12,000 |

| ID | Activity | Duration | Start | Finish | Predecessors | Planned start | Planned finish | Total float | Free float | Resources | Cost |
| --- | --- | --- | --- | --- | --- | --- | --- | --- | --- | --- | --- |
| 21 22 | 21 22 | 0d | 2000-09-14 | 2000-09-13 | 18 21 | 2000-09-14 | 2000-09-14 | 8d |  |  |  |
| 23 24 | SPREAD FOOTINGS OFFICE | 4d | 2000-09-14 | 2000-09-19 | 14 23, 213 23 |  |  | 38d | 0d | COST; Carpenters [128 h]; LB [64 h] | 17,500 |
| 20 22 | UNDERSLAB CONDUIT P-W | 5d | 2000-09-19 | 2000-09-25 | 19 20 |  |  | 0d |  | COST; Electricians [240 h] | 7,500 |
| 24 25 | FORM AND POUR GRADE BEAMS OFFICE | 6d | 2000-09-20 | 2000-09-27 | 23 24 |  |  | 38d | 0d | COST; Carpenters [192 h]; LB [96 h] | 21,000 |
| 22 29 | FORM AND POUR SLABS P-W | 10d | 2000-09-26 | 2000-10-09 | 18 22, 20 22, 21 22 |  |  | 0d |  | COST; Carpenters [320 h]; LB [160 h] | 225,000 |
| 25 26 | BACKFILL AND COMPACT OFFICE | 1d | 2000-09-28 | 2000-09-28 | 24 25 |  |  | 38d | 0d | COST; OP [40 h] | 1,800 |
| 26 27 | UNDERSLAB PLUMBING OFFICE | 3d | 2000-09-29 | 2000-10-03 | 25 26 |  |  | 38d | 0d | COST; Plumbers [96 h] | 9,000 |
| 27 28 | UNDERSLAB CONDUIT OFFICE | 3d | 2000-10-04 | 2000-10-06 | 26 27 |  |  | 38d | 0d | COST; Carpenters [96 h]; LB [48 h] | 5,000 |
| 28 99 | FORM AND POUR SLABS OFFICE | 3d | 2000-10-09 | 2000-10-11 | 27 28 |  |  | 38d | 0d | COST; Carpenters [96 h]; LB [48 h] | 18,000 |
| 29 30 | ERECT STRUCTURAL STEEL P-W | 10d | 2000-10-10 | 2000-10-23 | 22 29 |  |  | 0d |  | COST; OP [160 h]; Iron Workers [480 h] | 50,000 |
| 99 59 | ERECT PRECAST STRUCTURE | 5d | 2000-10-12 | 2000-10-18 | 28 99, 234 99 |  |  | 38d | 0d | COST; OP [40 h]; Carpenters [80 h]; LB [80 h] | 20,000 |
| 59 60 | ERECT PRECAST ROOF OFFICE | 5d | 2000-10-19 | 2000-10-25 | 99 59 |  |  | 38d | 30d | COST; OP [40 h]; Carpenters [80 h]; LB [80 h] | 30,000 |
| 30 31 | PLUMB AND BOLT STEEL P-W | 5d | 2000-10-24 | 2000-10-30 | 29 30 |  |  | 0d |  | COST; OP [80 h]; Iron Workers [240 h] | 15,000 |
| 31 32 | ERECT CRANEWAY AND CRANE P-W | 5d | 2000-10-31 | 2000-11-06 | 30 31, 215 31 |  |  | 0d |  | COST; Iron Workers [160 h] | 20,000 |
| 31 33 | ERECT MONORAIL TRACK P-W | 3d | 2000-10-31 | 2000-11-02 | 30 31, 215 31 |  |  | 2d |  | COST; Iron Workers [96 h] | 10,000 |
| 32 33 | 32 33 | 0d | 2000-11-07 | 2000-11-06 | 31 32 | 2000-11-07 | 2000-11-07 | 0d |  |  |  |
| 33 34 | ERECT BAR JOISTS P-W | 3d | 2000-11-07 | 2000-11-09 | 31 33, 32 33, 217 33 |  |  | 0d |  | COST; OP [48 h]; Iron Workers [144 h] | 15,000 |
| 34 35 | ERECT ROOF PLANKS P-W | 3d | 2000-11-10 | 2000-11-14 | 33 34 |  |  | 0d |  | COST; LB [48 h]; OP [48 h]; Carpenters [48 h] | 15,000 |
| 35 36 | ERECT SIDING P-W | 10d | 2000-11-15 | 2000-11-29 | 34 35, 219 35 |  |  | 0d |  | COST; OP [160 h]; Iron Workers [480 h] | 75,000 |
| 35 37 | BUILT-UP ROOFING P-W | 5d | 2000-11-15 | 2000-11-21 | 34 35, 219 35 |  |  | 5d |  | COST; Roofers [320 h] | 175,000 |
| 36 37 | 36 37 | 0d | 2000-11-30 | 2000-11-29 | 35 36 | 2000-11-30 | 2000-11-30 | 0d |  |  |  |
| 37 80 | PERIMETER FENCE | 10d | 2000-11-30 | 2000-12-13 | 35 37, 36 37 |  |  | 78d |  | COST; LB [480 h] | 25,000 |
| 37 90 | PAVE PARKING AREA | 5d | 2000-11-30 | 2000-12-06 | 35 37, 36 37 |  |  | 73d | 0d | COST; OP [160 h]; LB [240 h] | 35,000 |
| 37 91 | GRADE AND BALLAST RAILROAD SIDING | 5d | 2000-11-30 | 2000-12-06 | 35 37, 36 37 |  |  | 63d | 0d | COST; OP [80 h]; LB [240 h] | 20,000 |
| 37 92 | ACCESS ROAD | 10d | 2000-11-30 | 2000-12-13 | 35 37, 36 37 |  |  | 68d | 0d | COST; OP [320 h]; LB [480 h] | 25,000 |
| 37 93 | AREA LIGHTING | 20d | 2000-11-30 | 2000-12-28 | 35 37, 36 37 |  |  | 68d | 0d | COST; Electricians [640 h] | 33,000 |
| 37 300 | 37 300 | 0d | 2000-11-30 | 2000-11-29 | 35 37, 36 37 | 2000-11-30 | 2000-11-30 | 0d |  |  |  |
| 37 301 | 37 301 | 0d | 2000-11-30 | 2000-11-29 | 35 37, 36 37 | 2000-11-30 | 2000-11-30 | 12d | 0d |  |  |
| 37 302 | 37 302 | 0d | 2000-11-30 | 2000-11-29 | 35 37, 36 37 | 2000-11-30 | 2000-11-30 | 23d | 0d |  |  |
| 37 303 | 37 303 | 0d | 2000-11-30 | 2000-11-29 | 35 37, 36 37 | 2000-11-30 | 2000-11-30 | 13d | 0d |  |  |
| 37 304 | 37 304 | 0d | 2000-11-30 | 2000-11-29 | 35 37, 36 37 | 2000-11-30 | 2000-11-30 | 23d | 0d |  |  |
| 37 305 | 37 305 | 0d | 2000-11-30 | 2000-11-29 | 35 37, 36 37 | 2000-11-30 | 2000-11-30 | 70d | 0d |  |  |
| 37 306 | 37 306 | 0d | 2000-11-30 | 2000-11-29 | 35 37, 36 37 | 2000-11-30 | 2000-11-30 | 43d | 0d |  |  |
| 37 307 | 37 307 | 0d | 2000-11-30 | 2000-11-29 | 35 37, 36 37 | 2000-11-30 | 2000-11-30 | 33d | 0d |  |  |
| 37 308 | 37 308 | 0d | 2000-11-30 | 2000-11-29 | 35 37, 36 37 | 2000-11-30 | 2000-11-30 | 73d | 0d |  |  |
| 300 38 | SET ELECTRICAL LOAD CENTER | 2d | 2000-11-30 | 2000-12-01 | 37 300, 221 300 |  |  | 0d |  | COST; Electricians [64 h] | 30,500 |
| 301 43 | INSTALL POWER PANEL BACKING BOXES | 10d | 2000-11-30 | 2000-12-13 | 37 301, 223 301 |  |  | 12d |  | COST; Electricians [480 h] | 18,000 |
| 302 42 | EXTERIOR DOORS P-W | 5d | 2000-11-30 | 2000-12-06 | 37 302, 225 302 |  |  | 23d | 10d | COST; Carpenters [80 h]; LB [80 h] | 30,000 |
| 303 39 | MASONRY PARTITIONS | 10d | 2000-11-30 | 2000-12-13 | 37 303 |  |  | 13d | 0d | COST; MA [800 h] | 80,000 |
| 304 46 | INSTALL HEATING AND VENTILATING UNITS | 15d | 2000-11-30 | 2000-12-20 | 37 304, 228 304 |  |  | 23d | 10d | COST; ST [960 h] | 120,000 |
| 305 47 | INSTALL FUEL OIL TANK | 3d | 2000-11-30 | 2000-12-04 | 37 305, 232 305 |  |  | 70d | 37d | COST; ST [96 h] | 15,000 |
| 306 41 | ERECT BOILERS AND AUXILIARIES | 25d | 2000-11-30 | 2001-01-05 | 37 306, 230 306 |  |  | 43d | 0d | COST; ST [800 h] | 25,000 |
| 307 40 | FABRICATE PIPING SYSTEMS | 30d | 2000-11-30 | 2001-01-12 | 37 307 |  |  | 33d | 0d | COST | 60,000 |
| 308 58 | INSTALL MONORAIL | 5d | 2000-11-30 | 2000-12-06 | 37 308 |  |  | 73d |  | COST; Iron Workers [160 h] | 25,000 |
| 38 43 | INSTALL POWER CONDUIT P-W | 20d | 2000-12-04 | 2001-01-02 | 300 38 |  |  | 0d |  | COST; Electricians [960 h] | 21,000 |
| 90 58 | 90 58 | 0d | 2000-12-07 | 2000-12-06 | 37 90 | 2000-12-07 | 2000-12-07 | 73d |  |  |  |
| 91 58 | INSTALL RAILROAD SIDING | 10d | 2000-12-07 | 2000-12-20 | 37 91 |  |  | 63d |  | COST; OP [160 h]; LB [480 h] | 50,000 |
| 60 61 | EXTERIOR MASONRY OFFICE | 10d | 2000-12-08 | 2000-12-21 | 59 60, 236 60 |  |  | 8d | 0d | COST; MA [800 h] | 380,000 |
| 60 76 | INSTALL PACKAGE AIR CONDITIONING | 5d | 2000-12-08 | 2000-12-14 | 59 60, 236 60 |  |  | 68d | 29d | COST; ST [80 h] | 40,000 |
| 39 42 | FRAME CEILING P-W | 5d | 2000-12-14 | 2000-12-20 | 303 39 |  |  | 13d | 0d | COST; Carpenters [240 h]; LB [80 h] | 25,000 |
| 92 58 | 92 58 | 0d | 2000-12-14 | 2000-12-13 | 37 92 | 2000-12-14 | 2000-12-14 | 68d |  |  |  |
| 42 44 | DRYWALL PARTITIONS P-W | 10d | 2000-12-21 | 2001-01-05 | 39 42, 302 42 |  |  | 13d | 0d | COST; Carpenters [480 h]; LB [160 h] | 35,000 |
| 61 62 | EXTERIOR DOORS OFFICE | 5d | 2000-12-22 | 2000-12-29 | 60 61 |  |  | 22d | 0d | COST; Carpenters [40 h]; LB [40 h] | 3,600 |
| 61 63 | PLACE SINGLE-PLY ROOFING OFFICE | 5d | 2000-12-22 | 2000-12-29 | 60 61 |  |  | 22d | 0d | COST; Roofers [320 h] | 32,000 |
| 61 64 | INSTALL PIPING OFFICE | 10d | 2000-12-22 | 2001-01-08 | 60 61 |  |  | 8d | 0d | COST; PF [320 h] | 9,000 |
| 61 65 | INSTALL BACKING BOXES | 4d | 2000-12-22 | 2000-12-28 | 60 61 |  |  | 8d | 0d | COST; Electricians [128 h] | 4,000 |
| 61 68 | GLAZE OFFICE | 5d | 2000-12-22 | 2000-12-29 | 60 61 |  |  | 22d | 14d | COST; GZ [320 h] | 12,000 |
| 61 77 | DUCTWORK OFFICE | 15d | 2000-12-22 | 2001-01-15 | 60 61 |  |  | 42d | 19d | COST; SM [480 h] | 16,000 |
| 65 66 | INSTALL CONDUIT OFFICE | 10d | 2000-12-29 | 2001-01-12 | 61 65 |  |  | 8d | 0d | COST; Electricians [480 h] | 9,000 |
| 93 80 | 93 80 | 0d | 2000-12-29 | 2000-12-28 | 37 93 | 2000-12-29 | 2000-12-29 | 68d |  |  |  |
| 62 63 | 62 63 | 0d | 2001-01-02 | 2000-12-29 | 61 62 | 2001-01-02 | 2001-01-02 | 22d | 0d |  |  |
| 63 68 | 63 68 | 0d | 2001-01-02 | 2000-12-29 | 61 63, 62 63 | 2001-01-02 | 2001-01-02 | 22d | 14d |  |  |
| 63 80 | PAINT EXTERIOR OFFICE | 5d | 2001-01-02 | 2001-01-08 | 61 63, 62 63 |  |  | 62d |  | COST; PA [320 h] | 6,000 |
| 43 49 | INSTALL BRANCH CONDUIT P-W | 15d | 2001-01-03 | 2001-01-23 | 38 43, 301 43 |  |  | 0d |  | COST; Electricians [720 h] | 29,000 |
| 41 47 | PREOPERATIONAL CHECK | 5d | 2001-01-08 | 2001-01-12 | 306 41 |  |  | 43d | 10d | COST; ST [80 h] | 2,000 |
| 44 45 | 44 45 | 0d | 2001-01-08 | 2001-01-05 | 42 44 | 2001-01-08 | 2001-01-08 | 37d | 12d |  |  |
| 44 46 | 44 46 | 0d | 2001-01-08 | 2001-01-05 | 42 44 | 2001-01-08 | 2001-01-08 | 13d | 0d |  |  |
| 44 48 | CERAMIC TILE | 10d | 2001-01-08 | 2001-01-19 | 42 44 |  |  | 18d | 0d | COST | 10,000 |
| 44 58 | HANG INTERIOR DOORS P-W | 10d | 2001-01-08 | 2001-01-19 | 42 44 |  |  | 43d |  | COST; Carpenters [160 h]; LB [160 h] | 20,000 |
| 46 52 | INSTALL DUCTWORK P-W | 25d | 2001-01-08 | 2001-02-09 | 44 46, 304 46 |  |  | 13d | 0d | COST; SM [800 h] | 25,000 |

| ID | Activity | Duration | Start | Finish | Predecessors | Planned start | Planned finish | Total float | Free float | Resources | Cost |
| --- | --- | --- | --- | --- | --- | --- | --- | --- | --- | --- | --- |
| 64 67 | TEST PIPING OFFICE | 4d | 2001-01-09 | 2001-01-12 | 61 64 |  |  | 8d | 0d | COST; PF [64 h] | 1,000 |
| 40 47 | TEST PIPING SYSTEMS P-W | 10d | 2001-01-15 | 2001-01-26 | 307 40 |  |  | 33d | 0d | COST; PF [320 h] | 5,000 |
| 66 67 | 66 67 | 0d | 2001-01-15 | 2001-01-12 | 65 66 | 2001-01-15 | 2001-01-15 | 8d | 0d |  |  |
| 66 74 | PULL WIRE OFFICE | 10d | 2001-01-15 | 2001-01-26 | 65 66 |  |  | 28d | 0d | COST; Electricians [480 h] | 10,000 |
| 67 68 | METAL STUDS OFFICE | 5d | 2001-01-15 | 2001-01-19 | 64 67, 66 67 |  |  | 8d | 0d | COST; Carpenters [400 h]; LB [400 h] | 5,000 |
| 48 53 | PAINT ROOMS P-W | 5d | 2001-01-22 | 2001-01-26 | 44 48 |  |  | 18d | 0d | COST; PA [400 h] | 15,000 |
| 68 69 | DRYWALL | 5d | 2001-01-22 | 2001-01-26 | 61 68, 63 68, 67 68 |  |  | 8d | 0d | COST; Carpenters [200 h]; LB [200 h] | 5,000 |
| 45 51 | ROOM OUTLETS P-W | 5d | 2001-01-24 | 2001-01-30 | 44 45, 49 45 |  |  | 25d | 0d | COST; Electricians [240 h] | 16,500 |
| 49 45 | 49 45 | 0d | 2001-01-24 | 2001-01-23 | 43 49 | 2001-01-24 | 2001-01-24 | 25d | 0d |  |  |
| 49 50 | PULL WIRE P-W | 15d | 2001-01-24 | 2001-02-13 | 43 49 |  |  | 0d |  | COST; Electricians [720 h] | 38,000 |
| 47 58 | LIGHT OFF BOILER AND TEST | 5d | 2001-01-29 | 2001-02-02 | 40 47, 41 47, 305 47 |  |  | 33d |  | COST; ST [80 h] | 1,500 |
| 53 57 | FLOOR TILE P-W | 10d | 2001-01-29 | 2001-02-09 | 48 53 |  |  | 18d | 0d | COST; TL [640 h] | 20,000 |
| 53 58 | INSTALL PLUMBING FIXTURES P-W | 10d | 2001-01-29 | 2001-02-09 | 48 53 |  |  | 28d |  | COST; Plumbers [320 h] | 20,000 |
| 69 70 | DRYWALL | 10d | 2001-01-29 | 2001-02-09 | 68 69 |  |  | 8d | 0d | COST; Carpenters [400 h]; LB [400 h] | 10,000 |
| 69 73 | CERAMIC TILE OFFICE | 10d | 2001-01-29 | 2001-02-09 | 68 69 |  |  | 33d | 20d | COST; TL [480 h] | 9,000 |
| 74 75 | INSTALL PANEL INTERNALS OFFICE | 5d | 2001-01-29 | 2001-02-02 | 66 74 |  |  | 28d | 0d | COST; Electricians [240 h] | 5,000 |
| 74 76 | 74 76 | 0d | 2001-01-29 | 2001-01-26 | 66 74 | 2001-01-29 | 2001-01-29 | 39d | 0d |  |  |
| 76 79 | A/C ELECTRICAL CONNECTIONS | 4d | 2001-01-29 | 2001-02-01 | 60 76, 74 76 |  |  | 39d | 11d | COST; Electricians [128 h] | 2,000 |
| 51 56 | INSTALL ELECTRICAL FIXTURES | 10d | 2001-01-31 | 2001-02-13 | 45 51, 226 51 |  |  | 25d |  | COST; Electricians [480 h] | 31,000 |
| 75 79 | TERMINATE WIRES OFFICE | 10d | 2001-02-05 | 2001-02-16 | 74 75 |  |  | 28d | 0d | COST; Electricians [480 h] | 7,500 |
| 52 58 | INSULATE HEATING AND VENTILATING SYSTEM P-W | 15d | 2001-02-12 | 2001-03-02 | 46 52 |  |  | 13d |  | COST; IN [720 h] | 10,000 |
| 57 58 | INSTALL FURNISHINGS P-W | 10d | 2001-02-12 | 2001-02-23 | 53 57 |  |  | 18d |  | COST; LB [480 h] | 30,000 |
| 70 71 | WOOD TRIM OFFICE | 10d | 2001-02-12 | 2001-02-23 | 69 70 |  |  | 8d | 0d | COST; Carpenters [320 h] | 12,000 |
| 70 77 | 70 77 | 0d | 2001-02-12 | 2001-02-09 | 69 70 | 2001-02-12 | 2001-02-12 | 23d | 0d |  |  |
| 77 78 | INSTALL CEILING GRID OFFICE | 5d | 2001-02-12 | 2001-02-16 | 61 77, 70 77 |  |  | 23d | 15d | COST; Carpenters [160 h]; LB [160 h] | 10,000 |
| 50 54 | INSTALL PANEL INTERNALS P-W | 5d | 2001-02-14 | 2001-02-20 | 49 50 |  |  | 0d |  | COST; Electricians [160 h] | 7,500 |
| 79 80 | RING OUT | 5d | 2001-02-19 | 2001-02-23 | 75 79, 76 79 |  |  | 28d |  | COST; Electricians [80 h] | 2,500 |
| 54 55 | TERMINATE WIRE P-W | 10d | 2001-02-21 | 2001-03-06 | 50 54 |  |  | 0d |  | COST; Electricians [320 h] | 7,500 |
| 71 72 | PAINT INTERIOR OFFICE | 10d | 2001-02-26 | 2001-03-09 | 70 71 |  |  | 8d | 0d | COST; PA [800 h] | 16,000 |
| 71 80 | HANG DOORS OFFICE | 5d | 2001-02-26 | 2001-03-02 | 70 71 |  |  | 23d |  | COST; Carpenters [160 h]; LB [160 h] | 10,000 |
| 55 56 | RING OUT P-W | 10d | 2001-03-07 | 2001-03-20 | 54 55 |  |  | 0d |  | COST; Electricians [320 h] | 5,000 |
| 72 73 | 72 73 | 0d | 2001-03-12 | 2001-03-09 | 71 72 | 2001-03-12 | 2001-03-12 | 13d | 0d |  |  |
| 72 78 | 72 78 | 0d | 2001-03-12 | 2001-03-09 | 71 72 | 2001-03-12 | 2001-03-12 | 8d | 0d |  |  |
| 72 80 | FLOOR TILE OFFICE | 10d | 2001-03-12 | 2001-03-23 | 71 72 |  |  | 8d |  | COST; TL [480 h] | 18,000 |
| 73 80 | TOILET FIXTURES OFFICE | 5d | 2001-03-12 | 2001-03-16 | 69 73, 72 73 |  |  | 13d |  | COST; Plumbers [160 h] | 10,000 |
| 78 80 | ACOUSTIC TILES OFFICE | 10d | 2001-03-12 | 2001-03-23 | 72 78, 77 78 |  |  | 8d |  | COST; Carpenters [160 h]; LB [160 h] | 20,000 |
| 56 58 | ENERGIZE POWER | 1d | 2001-03-21 | 2001-03-21 | 51 56, 55 56 |  |  | 0d |  | COST; Electricians [16 h] | 2,000 |
| 58 80 | ERECT FLAGPOLE | 5d | 2001-03-22 | 2001-03-28 | 44 58, 47 58, 52 58, 53 58, 56 58, 57 58, 90 58, 91 58, 92 58, 308 58 |  |  | 5d |  | COST; LB [80 h] | 1,500 |
| 58 94 | FINE GRADE | 5d | 2001-03-22 | 2001-03-28 | 44 58, 47 58, 52 58, 53 58, 56 58, 57 58, 90 58, 91 58, 92 58, 308 58 |  |  | 0d |  | COST; OP [80 h] | 5,000 |
| 94 80 | SEED AND PLANT | 5d | 2001-03-29 | 2001-04-04 | 58 94 |  |  | 0d |  | COST; LB [240 h] | 20,000 |
| 80 | END OF NETWORK | 1d | 2001-04-05 | 2001-04-05 | 37 80, 58 80, 63 80, 71 80, 72 80, 73 80, 78 80, 79 80, 93 80, 94 80 |  |  | 0d |  |  |  |

# JOHN DOE PROJECT ADM-PDM VERSION

Schedule from Primavera P6, 2000-06-05 to 2001-05-30, data date 2000-06-05, costs in USD, A marks actual dates.

## Calendars

- DPAB - 1: Mon-Fri 08:00-12:00, 13:00-17:00; Sat-Sun off. Exceptions (off unless hours are given): 2000-07-04, 2000-09-04, 2000-11-23, 2000-12-25, 2001-01-01, 2001-05-28.

## Resources

| Resource | Group |
| --- | --- |
| COST | labor |
| OP | labor |
| SV | labor |
| Plumbers | labor |
| Carpenters | labor |
| LB | labor |
| Electricians | labor |
| BM | labor |
| Iron Workers | labor |
| Roofers | labor |
| PF | labor |
| ST | labor |
| SM | labor |
| PA | labor |
| IN | labor |
| TL | labor |
| MA | labor |
| GZ | labor |

## Schedule

| ID | Activity | Duration | Start | Finish | Predecessors | Complete | Planned start | Planned finish | Resources | Cost |
| --- | --- | --- | --- | --- | --- | --- | --- | --- | --- | --- |
| 0 | START OF NETWORK | 1d | 2000-06-05 A | 2000-06-05 A |  | 100% |  |  |  |  |
| 0 1 | CLEAR SITE | 3d | 2000-06-05 A | 2000-06-09 A | 0 | 100% | 2000-06-05 | 2000-06-07 | COST; OP [120 h] | 28,000 |
| 0 233 | SUBMIT PRECAST | 40d | 2000-06-05 A | 2000-08-04 A | 0 | 100% | 2000-06-05 | 2000-07-31 |  |  |
| 1 2 | SURVEY AND LAYOUT | 2d | 2000-06-05 A | 2000-06-12 A | 0 1 | 100% | 2000-06-05 | 2000-06-06 | COST; SV [48 h] | 2,500 |
| 2 3 | ROUGH GRADE | 2d | 2000-06-05 A | 2000-06-15 A | 1 2 | 100% | 2000-06-05 | 2000-06-06 | COST; OP [48 h] | 10,000 |
| 3 4 | DRILL WELL | 15d | 2000-06-05 A | 2000-07-06 A | 2 3 | 100% | 2000-06-05 | 2000-06-23 | COST; Plumbers [240 h] | 10,000 |
| 3 6 | WATER TANK FOUNDATIONS | 4d | 2000-06-05 A | 2000-08-21 A | 2 3 | 100% | 2000-06-05 | 2000-06-08 | COST; Carpenters [128 h]; LB [64 h] | 5,000 |
| 3 9 | EXCAVATE FOR SEWER | 10d | 2000-06-05 A | 2000-07-05 A | 2 3 | 100% | 2000-06-05 | 2000-06-16 | COST; OP [400 h] | 21,500 |
| 3 10 | EXCAVATE ELECTRIC MANHOLES | 1d | 2000-06-05 A | 2000-06-16 A | 2 3 | 100% | 2000-06-05 | 2000-06-05 | COST; OP [16 h] | 1,000 |
| 3 12 | OVERHEAD POLE LINE | 6d | 2000-06-05 A | 2000-06-26 A | 2 3 | 100% | 2000-06-05 | 2000-06-12 | COST; Electricians [192 h] | 30,000 |
| 4 5 | INSTALL WELL PUMP | 2d | 2000-06-05 A | 2000-08-14 A | 3 4 | 100% | 2000-06-05 | 2000-06-06 | COST; Plumbers [32 h] | 11,250 |
| 5 8 | UNDERGROUND WATER PIPING | 8d | 2000-06-05 A | 2000-08-25 A | 4 5 | 100% | 2000-06-05 | 2000-06-14 | COST; Plumbers [128 h] | 18,000 |
| 6 7 | ERECT WATER TANK | 10d | 2000-06-05 A | 2000-09-01 A | 3 6 | 100% | 2000-06-05 | 2000-06-16 | COST; BM [640 h] | 225,000 |
| 7 8 | TANK PIPING & VALVES | 10d | 2000-06-05 A | 2000-09-01 A | 6 7 | 100% | 2000-06-05 | 2000-06-16 | COST; BM [320 h] | 40,000 |
| 8 13 | CONNECT WATER PIPING | 2d | 2000-06-05 A | 2000-09-04 A | 5 8, 7 8 | 100% | 2000-06-05 | 2000-06-06 | COST; BM [64 h] | 2,000 |
| 9 11 | INSTALL SEWER AND BACKFILL | 5d | 2000-06-05 A | 2000-07-12 A | 3 9 | 100% | 2000-06-05 | 2000-06-09 | COST; Plumbers [240 h] | 65,000 |
| 10 11 | INSTALL ELECTRICAL MANHOLES | 5d | 2000-06-05 A | 2000-06-23 A | 3 10 | 100% | 2000-06-05 | 2000-06-09 | COST; Carpenters [160 h]; LB [80 h] | 6,500 |
| 11 12 | INSTALL ELECTRICAL DUCT BANK | 3d | 2000-06-05 A | 2000-07-14 A | 9 11, 10 11 | 100% | 2000-06-05 | 2000-06-07 | COST; Electricians [144 h] | 7,500 |
| 12 13 | PULL IN FEEDER | 5d | 2000-06-05 A | 2000-07-21 A | 3 12, 11 12 | 100% | 2000-06-05 | 2000-06-09 | COST; Electricians [160 h] | 6,000 |
| 13 14 | BUILDING LAYOUT | 1d | 2000-06-05 A | 2000-07-12 A | 8 13, 12 13 | 100% | 2000-06-05 | 2000-06-05 | COST; SV [24 h] | 4,000 |
| 14 15 | DRIVE AND POUR PILES | 10d | 2000-06-05 A | 2000-08-07 A | 13 14 | 100% | 2000-06-05 | 2000-06-16 | COST; OP [160 h]; Carpenters [160 h]; LB [160 h] | 70,000 |
| 14 23 | EXCAVATE FOR OFFICE BUILDING | 3d | 2000-06-05 A | 2000-09-08 A | 13 14 | 100% | 2000-06-05 | 2000-06-07 | COST; OP [120 h] | 27,000 |
| 15 16 | EXCAVATE PLANT WAREHOUSE | 5d | 2000-06-05 A | 2000-08-09 A | 14 15 | 100% | 2000-06-05 | 2000-06-09 | COST; OP [200 h] | 86,000 |
| 16 17 | POUR PILE CAPS P-W | 5d | 2000-06-05 A | 2000-08-11 A | 15 16, 211 16 | 100% | 2000-06-05 | 2000-06-09 | COST; Carpenters [160 h]; LB [800 h] | 50,000 |
| 17 18 | FORM AND POUR GRADE BEAMS P-W | 10d | 2000-06-05 A | 2000-08-18 A | 16 17 | 100% | 2000-06-05 | 2000-06-16 | COST; Carpenters [160 h]; LB [160 h] | 70,000 |
| 18 19 | BACKFILL AND COMPACT P-W | 3d | 2000-06-05 A | 2000-08-18 A | 17 18 | 100% | 2000-06-05 | 2000-06-07 | COST; OP [120 h] | 9,000 |
| 18 21 | FORM AND POUR RAILROAD LOADING DOCK P-W | 5d | 2000-06-05 A | 2000-08-25 A | 17 18 | 100% | 2000-06-05 | 2000-06-09 | COST; Carpenters [160 h]; LB [80 h] | 15,000 |
| 18 22 | FORM AND POUR TRUCK LOADING DOCK P-W | 5d | 2000-06-05 A | 2000-08-25 A | 17 18 | 100% | 2000-06-05 | 2000-06-09 | COST; Carpenters [160 h]; LB [80 h] | 15,000 |
| 19 20 | UNDERSLAB PLUMBING P-W | 5d | 2000-06-05 A | 2000-08-23 A | 18 19 | 100% | 2000-06-05 | 2000-06-09 | COST; Plumbers [160 h] | 12,000 |
| 20 22 | UNDERSLAB CONDUIT P-W | 5d | 2000-06-05 A | 2000-08-25 A | 19 20 | 100% | 2000-06-05 | 2000-06-09 | COST; Electricians [240 h] | 7,500 |
| 22 29 | FORM AND POUR SLABS P-W | 10d | 2000-06-05 A | 2000-09-04 A | 18 22, 20 22, 21 22 | 100% | 2000-06-05 | 2000-06-16 | COST; Carpenters [320 h]; LB [160 h] | 225,000 |
| 23 24 | SPREAD FOOTINGS OFFICE | 4d | 2000-06-05 A | 2000-09-13 A | 14 23, 213 23 | 100% | 2000-06-05 | 2000-06-08 | COST; Carpenters [128 h]; LB [64 h] | 17,500 |
| 24 25 | FORM AND POUR GRADE BEAMS OFFICE | 6d | 2000-06-05 A | 2000-09-20 A | 23 24 | 100% | 2000-06-05 | 2000-06-12 | COST; Carpenters [192 h]; LB [96 h] | 21,000 |
| 25 26 | BACKFILL AND COMPACT OFFICE | 1d | 2000-06-05 A | 2000-09-20 A | 24 25 | 100% | 2000-06-05 | 2000-06-05 | COST; OP [40 h] | 1,800 |
| 26 27 | UNDERSLAB PLUMBING OFFICE | 3d | 2000-06-05 A | 2000-09-22 A | 25 26 | 100% | 2000-06-05 | 2000-06-07 | COST; Plumbers [96 h] | 9,000 |
| 27 28 | UNDERSLAB CONDUIT OFFICE | 3d | 2000-06-05 A | 2000-09-22 A | 26 27 | 100% | 2000-06-05 | 2000-06-07 | COST; Carpenters [96 h]; LB [48 h] | 5,000 |
| 28 99 | FORM AND POUR SLABS OFFICE | 3d | 2000-06-05 A | 2000-09-29 A | 27 28 | 100% | 2000-06-05 | 2000-06-07 | COST; Carpenters [96 h]; LB [48 h] | 18,000 |
| 29 30 | ERECT STRUCTURAL STEEL P-W | 10d | 2000-06-05 A | 2000-11-20 A | 22 29 | 100% | 2000-06-05 | 2000-06-16 | COST; OP [160 h]; Iron Workers [480 h] | 50,000 |
| 30 31 | PLUMB AND BOLT STEEL P-W | 5d | 2000-06-05 A | 2000-11-22 A | 29 30 | 100% | 2000-06-05 | 2000-06-09 | COST; OP [80 h]; Iron Workers [240 h] | 15,000 |
| 31 32 | ERECT CRANEWAY AND CRANE P-W | 5d | 2000-06-05 A | 2000-11-27 A | 30 31, 215 31 | 100% | 2000-06-05 | 2000-06-09 | COST; Iron Workers [160 h] | 20,000 |
| 31 33 | ERECT MONORAIL TRACK P-W | 3d | 2000-06-05 A | 2000-11-27 A | 30 31, 215 31 | 100% | 2000-06-05 | 2000-06-07 | COST; Iron Workers [96 h] | 10,000 |
| 33 34 | ERECT BAR JOISTS P-W | 3d | 2000-06-05 A | 2000-12-04 A | 31 33, 32 33, 217 33 | 100% | 2000-06-05 | 2000-06-07 | COST; OP [48 h]; Iron Workers [144 h] | 15,000 |
| 34 35 | ERECT ROOF PLANKS P-W | 3d | 2000-06-05 A | 2001-01-15 A | 33 34 | 100% | 2000-06-05 | 2000-06-07 | COST; LB [48 h]; OP [48 h]; Carpenters [48 h] | 15,000 |
| 35 36 | ERECT SIDING P-W | 10d | 2000-06-05 A | 2001-01-29 A | 34 35, 219 35 | 100% | 2000-06-05 | 2000-06-16 | COST; OP [160 h]; Iron Workers [480 h] | 75,000 |
| 35 37 | BUILT-UP ROOFING P-W | 5d | 2000-06-05 A | 2001-02-02 A | 34 35, 219 35 | 100% | 2000-06-05 | 2000-06-09 | COST; Roofers [320 h] | 175,000 |
| 37 80 | PERIMETER FENCE | 10d | 2000-06-05 A | 2001-05-23 A | 35 37, 36 37 | 100% | 2000-06-05 | 2000-06-16 | COST; LB [480 h] | 25,000 |
| 37 90 | PAVE PARKING AREA | 5d | 2000-06-05 A | 2001-05-14 A | 35 37, 36 37 | 100% | 2000-06-05 | 2000-06-09 | COST; OP [160 h]; LB [240 h] | 35,000 |
| 37 91 | GRADE AND BALLAST RAILROAD SIDING | 5d | 2000-06-05 A | 2001-04-02 A | 35 37, 36 37 | 100% | 2000-06-05 | 2000-06-09 | COST; OP [80 h]; LB [240 h] | 20,000 |
| 37 92 | ACCESS ROAD | 10d | 2000-06-05 A | 2001-05-14 A | 35 37, 36 37 | 100% | 2000-06-05 | 2000-06-16 | COST; OP [320 h]; LB [480 h] | 25,000 |
| 37 93 | AREA LIGHTING | 20d | 2000-06-05 A | 2001-05-21 A | 35 37, 36 37 | 100% | 2000-06-05 | 2000-06-30 | COST; Electricians [640 h] | 33,000 |
| 38 43 | INSTALL POWER CONDUIT P-W | 20d | 2000-06-05 A | 2001-03-07 A | 300 38 | 100% | 2000-06-05 | 2000-06-30 | COST; Electricians [960 h] | 21,000 |
| 39 42 | FRAME CEILING P-W | 5d | 2000-06-05 A | 2001-03-26 A | 303 39 | 100% | 2000-06-05 | 2000-06-09 | COST; Carpenters [240 h]; LB [80 h] | 25,000 |
| 40 47 | TEST PIPING SYSTEMS P-W | 10d | 2000-06-05 A | 2001-05-03 A | 307 40 | 100% | 2000-06-05 | 2000-06-16 | COST; PF [320 h] | 5,000 |
| 41 47 | PREOPERATIONAL CHECK | 5d | 2000-06-05 A | 2001-05-14 A | 306 41 | 100% | 2000-06-05 | 2000-06-09 | COST; ST [80 h] | 2,000 |
| 42 44 | DRYWALL PARTITIONS P-W | 10d | 2000-06-05 A | 2001-04-04 A | 39 42, 302 42 | 100% | 2000-06-05 | 2000-06-16 | COST; Carpenters [480 h]; LB [160 h] | 35,000 |
| 43 49 | INSTALL BRANCH CONDUIT P-W | 15d | 2000-06-05 A | 2001-03-21 A | 38 43, 301 43 | 100% | 2000-06-05 | 2000-06-23 | COST; Electricians [720 h] | 29,000 |
| 44 48 | CERAMIC TILE | 10d | 2000-06-05 A | 2001-04-19 A | 42 44 | 100% | 2000-06-05 | 2000-06-16 | COST | 10,000 |
| 44 58 | HANG INTERIOR DOORS P-W | 10d | 2000-06-05 A | 2001-05-14 A | 42 44 | 100% | 2000-06-05 | 2000-06-16 | COST; Carpenters [160 h]; LB [160 h] | 20,000 |
| 45 51 | ROOM OUTLETS P-W | 5d | 2000-06-05 A | 2001-04-30 A | 44 45, 49 45 | 100% | 2000-06-05 | 2000-06-09 | COST; Electricians [240 h] | 16,500 |
| 46 52 | INSTALL DUCTWORK P-W | 25d | 2000-06-05 A | 2001-04-04 A | 44 46, 304 46 | 100% | 2000-06-05 | 2000-07-10 | COST; SM [800 h] | 25,000 |
| 47 58 | LIGHT OFF BOILER AND TEST | 5d | 2000-06-05 A | 2001-05-21 A | 40 47, 41 47, 305 47 | 100% | 2000-06-05 | 2000-06-09 | COST; ST [80 h] | 1,500 |
| 48 53 | PAINT ROOMS P-W | 5d | 2000-06-05 A | 2001-04-19 A | 44 48 | 100% | 2000-06-05 | 2000-06-09 | COST; PA [400 h] | 15,000 |
| 49 50 | PULL WIRE P-W | 15d | 2000-06-05 A | 2001-03-21 A | 43 49 | 100% | 2000-06-05 | 2000-06-23 | COST; Electricians [720 h] | 38,000 |
| 50 54 | INSTALL PANEL INTERNALS P-W | 5d | 2000-06-05 A | 2001-05-14 A | 49 50 | 100% | 2000-06-05 | 2000-06-09 | COST; Electricians [160 h] | 7,500 |
| 51 56 | INSTALL ELECTRICAL FIXTURES | 10d | 2000-06-05 A | 2001-05-14 A | 45 51, 226 51 | 100% | 2000-06-05 | 2000-06-16 | COST; Electricians [480 h] | 31,000 |
| 52 58 | INSULATE HEATING AND VENTILATING SYSTEM P-W | 15d | 2000-06-05 A | 2001-04-20 A | 46 52 | 100% | 2000-06-05 | 2000-06-23 | COST; IN [720 h] | 10,000 |
| 53 57 | FLOOR TILE P-W | 10d | 2000-06-05 A | 2001-05-03 A | 48 53 | 100% | 2000-06-05 | 2000-06-16 | COST; TL [640 h] | 20,000 |
| 53 58 | INSTALL PLUMBING FIXTURES P-W | 10d | 2000-06-05 A | 2001-05-23 A | 48 53 | 100% | 2000-06-05 | 2000-06-16 | COST; Plumbers [320 h] | 20,000 |
| 54 55 | TERMINATE WIRE P-W | 10d | 2000-06-05 A | 2001-04-30 A | 50 54 | 100% | 2000-06-05 | 2000-06-16 | COST; Electricians [320 h] | 7,500 |
| 55 56 | RING OUT P-W | 10d | 2000-06-05 A | 2001-05-14 A | 54 55 | 100% | 2000-06-05 | 2000-06-16 | COST; Electricians [320 h] | 5,000 |

| ID | Activity | Duration | Start | Finish | Predecessors | Complete | Planned start | Planned finish | Resources | Cost |
| --- | --- | --- | --- | --- | --- | --- | --- | --- | --- | --- |
| 56 58 | ENERGIZE POWER | 1d | 2000-06-05 A | 2001-05-14 A | 51 56, 55 56 | 100% | 2000-06-05 | 2000-06-05 | COST; Electricians [16 h] | 2,000 |
| 57 58 | INSTALL FURNISHINGS P-W | 10d | 2000-06-05 A | 2001-05-14 A | 53 57 | 100% | 2000-06-05 | 2000-06-16 | COST; LB [480 h] | 30,000 |
| 58 80 | ERECT FLAGPOLE | 5d | 2000-06-05 A | 2001-05-30 A | 44 58, 47 58, 52 58, 53 58, 56 58, 57 58, 90 58, 91 58, 92 58, 308 58 | 100% | 2000-06-05 | 2000-06-09 | COST; LB [80 h] | 1,500 |
| 58 94 | FINE GRADE | 5d | 2000-06-05 A | 2001-05-14 A | 44 58, 47 58, 52 58, 53 58, 56 58, 57 58, 90 58, 91 58, 92 58, 308 58 | 100% | 2000-06-05 | 2000-06-09 | COST; OP [80 h] | 5,000 |
| 59 60 | ERECT PRECAST ROOF OFFICE | 5d | 2000-06-05 A | 2001-02-21 A | 99 59 | 100% | 2000-06-05 | 2000-06-09 | COST; OP [40 h]; Carpenters [80 h]; LB [80 h] | 30,000 |
| 60 61 | EXTERIOR MASONRY OFFICE | 10d | 2000-06-05 A | 2001-03-05 A | 59 60, 236 60 | 100% | 2000-06-05 | 2000-06-16 | COST; MA [800 h] | 380,000 |
| 60 76 | INSTALL PACKAGE AIR CONDITIONING | 5d | 2000-06-05 A | 2001-05-14 A | 59 60, 236 60 | 100% | 2000-06-05 | 2000-06-09 | COST; ST [80 h] | 40,000 |
| 61 62 | EXTERIOR DOORS OFFICE | 5d | 2000-06-05 A | 2001-03-14 A | 60 61 | 100% | 2000-06-05 | 2000-06-09 | COST; Carpenters [40 h]; LB [40 h] | 3,600 |
| 61 63 | PLACE SINGLE-PLY ROOFING OFFICE | 5d | 2000-06-05 A | 2001-03-14 A | 60 61 | 100% | 2000-06-05 | 2000-06-09 | COST; Roofers [320 h] | 32,000 |
| 61 64 | INSTALL PIPING OFFICE | 10d | 2000-06-05 A | 2001-03-05 A | 60 61 | 100% | 2000-06-05 | 2000-06-16 | COST; PF [320 h] | 9,000 |
| 61 65 | INSTALL BACKING BOXES | 4d | 2000-06-05 A | 2001-03-01 A | 60 61 | 100% | 2000-06-05 | 2000-06-08 | COST; Electricians [128 h] | 4,000 |
| 61 68 | GLAZE OFFICE | 5d | 2000-06-05 A | 2001-03-26 A | 60 61 | 100% | 2000-06-05 | 2000-06-09 | COST; GZ [320 h] | 12,000 |
| 61 77 | DUCTWORK OFFICE | 15d | 2000-06-05 A | 2001-05-03 A | 60 61 | 100% | 2000-06-05 | 2000-06-23 | COST; SM [480 h] | 16,000 |
| 63 80 | PAINT EXTERIOR OFFICE | 5d | 2000-06-05 A | 2001-05-14 A | 61 63, 62 63 | 100% | 2000-06-05 | 2000-06-09 | COST; PA [320 h] | 6,000 |
| 64 67 | TEST PIPING OFFICE | 4d | 2000-06-05 A | 2001-03-09 A | 61 64 | 100% | 2000-06-05 | 2000-06-08 | COST; PF [64 h] | 1,000 |
| 65 66 | INSTALL CONDUIT OFFICE | 10d | 2000-06-05 A | 2001-03-16 A | 61 65 | 100% | 2000-06-05 | 2000-06-16 | COST; Electricians [480 h] | 9,000 |
| 66 74 | PULL WIRE OFFICE | 10d | 2000-06-05 A | 2001-04-04 A | 65 66 | 100% | 2000-06-05 | 2000-06-16 | COST; Electricians [480 h] | 10,000 |
| 67 68 | METAL STUDS OFFICE | 5d | 2000-06-05 A | 2001-03-16 A | 64 67, 66 67 | 100% | 2000-06-05 | 2000-06-09 | COST; Carpenters [400 h]; LB [400 h] | 5,000 |
| 68 69 | DRYWALL | 5d | 2000-06-05 A | 2001-03-21 A | 61 68, 63 68, 67 68 | 100% | 2000-06-05 | 2000-06-09 | COST; Carpenters [200 h]; LB [200 h] | 5,000 |
| 69 70 | DRYWALL | 10d | 2000-06-05 A | 2001-04-06 A | 68 69 | 100% | 2000-06-05 | 2000-06-16 | COST; Carpenters [400 h]; LB [400 h] | 10,000 |
| 69 73 | CERAMIC TILE OFFICE | 10d | 2000-06-05 A | 2001-05-21 A | 68 69 | 100% | 2000-06-05 | 2000-06-16 | COST; TL [480 h] | 9,000 |
| 70 71 | WOOD TRIM OFFICE | 10d | 2000-06-05 A | 2001-04-19 A | 69 70 | 100% | 2000-06-05 | 2000-06-16 | COST; Carpenters [320 h] | 12,000 |
| 71 72 | PAINT INTERIOR OFFICE | 10d | 2000-06-05 A | 2001-05-21 A | 70 71 | 100% | 2000-06-05 | 2000-06-16 | COST; PA [800 h] | 16,000 |
| 71 80 | HANG DOORS OFFICE | 5d | 2000-06-05 A | 2001-05-21 A | 70 71 | 100% | 2000-06-05 | 2000-06-09 | COST; Carpenters [160 h]; LB [160 h] | 10,000 |
| 72 80 | FLOOR TILE OFFICE | 10d | 2000-06-05 A | 2001-05-21 A | 71 72 | 100% | 2000-06-05 | 2000-06-16 | COST; TL [480 h] | 18,000 |
| 73 80 | TOILET FIXTURES OFFICE | 5d | 2000-06-05 A | 2001-05-21 A | 69 73, 72 73 | 100% | 2000-06-05 | 2000-06-09 | COST; Plumbers [160 h] | 10,000 |
| 74 75 | INSTALL PANEL INTERNALS OFFICE | 5d | 2000-06-05 A | 2001-05-04 A | 66 74 | 100% | 2000-06-05 | 2000-06-09 | COST; Electricians [240 h] | 5,000 |
| 75 79 | TERMINATE WIRES OFFICE | 10d | 2000-06-05 A | 2001-05-14 A | 74 75 | 100% | 2000-06-05 | 2000-06-16 | COST; Electricians [480 h] | 7,500 |
| 76 79 | A/C ELECTRICAL CONNECTIONS | 4d | 2000-06-05 A | 2001-05-18 A | 60 76, 74 76 | 100% | 2000-06-05 | 2000-06-08 | COST; Electricians [128 h] | 2,000 |
| 77 78 | INSTALL CEILING GRID OFFICE | 5d | 2000-06-05 A | 2001-05-03 A | 61 77, 70 77 | 100% | 2000-06-05 | 2000-06-09 | COST; Carpenters [160 h]; LB [160 h] | 10,000 |
| 78 80 | ACOUSTIC TILES OFFICE | 10d | 2000-06-05 A | 2001-05-21 A | 72 78, 77 78 | 100% | 2000-06-05 | 2000-06-16 | COST; Carpenters [160 h]; LB [160 h] | 20,000 |
| 79 80 | RING OUT | 5d | 2000-06-05 A | 2001-05-21 A | 75 79, 76 79 | 100% | 2000-06-05 | 2000-06-09 | COST; Electricians [80 h] | 2,500 |
| 91 58 | INSTALL RAILROAD SIDING | 10d | 2000-06-05 A | 2001-05-14 A | 37 91 | 100% | 2000-06-05 | 2000-06-16 | COST; OP [160 h]; LB [480 h] | 50,000 |
| 94 80 | SEED AND PLANT | 5d | 2000-06-05 A | 2001-05-21 A | 58 94 | 100% | 2000-06-05 | 2000-06-09 | COST; LB [240 h] | 20,000 |
| 99 59 | ERECT PRECAST STRUCTURE | 5d | 2000-06-05 A | 2001-02-13 A | 28 99, 234 99 | 100% | 2000-06-05 | 2000-06-09 | COST; OP [40 h]; Carpenters [80 h]; LB [80 h] | 20,000 |
| 213 23 | FAB/DEL STRUCTURAL STEEL | 40d | 2000-06-05 A | 2000-11-03 A | 212 213 | 100% | 2000-06-05 | 2000-07-31 | COST | 550,000 |
| 215 31 | FAB/DEL CRANE | 50d | 2000-06-05 A | 2000-11-13 A | 214 215 | 100% | 2000-06-05 | 2000-08-14 | COST | 180,000 |
| 217 33 | FAB/DEL BAR JOISTS | 30d | 2000-06-05 A | 2000-10-20 A | 216 217 | 100% | 2000-06-05 | 2000-07-17 | COST | 60,000 |
| 219 35 | FAB/DEL SIDING | 40d | 2000-06-05 A | 2000-11-20 A | 218 219 | 100% | 2000-06-05 | 2000-07-31 | COST | 300,000 |
| 225 226 | APPROVE PLANT ELECTRICAL FIXTURES | 15d | 2000-06-05 A | 2000-08-15 A | 0 225, 224 225 | 100% | 2000-06-05 | 2000-06-23 | COST | 60,000 |
| 234 99 | FAB/DEL PRECAST | 30d | 2000-06-05 A | 2001-02-02 A | 233 234 | 100% | 2000-06-05 | 2000-07-17 | COST | 70,000 |
| 300 38 | SET ELECTRICAL LOAD CENTER | 2d | 2000-06-05 A | 2000-12-19 A | 37 300, 221 300 | 100% | 2000-06-05 | 2000-06-06 | COST; Electricians [64 h] | 30,500 |
| 301 43 | INSTALL POWER PANEL BACKING BOXES | 10d | 2000-06-05 A | 2001-03-20 A | 37 301, 223 301 | 100% | 2000-06-05 | 2000-06-16 | COST; Electricians [480 h] | 18,000 |
| 302 42 | EXTERIOR DOORS P-W | 5d | 2000-06-05 A | 2001-03-26 A | 37 302, 225 302 | 100% | 2000-06-05 | 2000-06-09 | COST; Carpenters [80 h]; LB [80 h] | 30,000 |
| 303 39 | MASONRY PARTITIONS | 10d | 2000-06-05 A | 2001-03-19 A | 37 303 | 100% | 2000-06-05 | 2000-06-16 | COST; MA [800 h] | 80,000 |
| 304 46 | INSTALL HEATING AND VENTILATING UNITS | 15d | 2000-06-05 A | 2001-03-28 A | 37 304, 228 304 | 100% | 2000-06-05 | 2000-06-23 | COST; ST [960 h] | 120,000 |
| 305 47 | INSTALL FUEL OIL TANK | 3d | 2000-06-05 A | 2001-05-01 A | 37 305, 232 305 | 100% | 2000-06-05 | 2000-06-07 | COST; ST [96 h] | 15,000 |
| 306 41 | ERECT BOILERS AND AUXILIARIES | 25d | 2000-06-05 A | 2001-03-06 A | 37 306, 230 306 | 100% | 2000-06-05 | 2000-07-10 | COST; ST [800 h] | 25,000 |
| 307 40 | FABRICATE PIPING SYSTEMS | 30d | 2000-06-05 A | 2001-03-23 A | 37 307 | 100% | 2000-06-05 | 2000-07-17 | COST | 60,000 |
| 308 58 | INSTALL MONORAIL | 5d | 2000-06-05 A | 2001-02-02 A | 37 308 | 100% | 2000-06-05 | 2000-06-09 | COST; Iron Workers [160 h] | 25,000 |
| 0 220 | SUBMIT PLANT ELECTRICAL LOAD CENTER | 20d | 2000-06-12 A | 2000-07-07 A | 0 | 100% | 2000-06-12 | 2000-07-10 |  |  |
| 0 222 | SUBMIT POWER PANELS - PLANT | 20d | 2000-06-12 A | 2000-07-07 A | 0 | 100% | 2000-06-12 | 2000-07-10 |  |  |
| 0 210 | SUBMIT FOUNDATION REBAR | 10d | 2000-06-19 A | 2000-07-05 A | 0 | 100% | 2000-06-19 | 2000-06-30 |  |  |
| 0 218 | SUBMIT SIDING | 20d | 2000-06-19 A | 2000-07-07 A | 0 | 100% | 2000-06-19 | 2000-07-17 |  |  |
| 0 235 | SUBMIT PACKAGED A/C | 30d | 2000-06-19 A | 2000-08-04 A | 0 | 100% | 2000-06-19 | 2000-07-31 |  |  |
| 0 212 | SUBMIT STRUCTURAL STEEL | 20d | 2000-06-30 A | 2000-07-28 A | 0 | 100% |  |  |  |  |
| 0 214 | SUBMIT CRANE | 20d | 2000-06-30 A | 2000-07-28 A | 0 | 100% |  |  |  |  |
| 0 216 | SUBMIT BAR JOISTS | 20d | 2000-06-30 A | 2000-07-28 A | 0 | 100% |  |  |  |  |
| 210 211 | APPROVE FOUNDATION REBAR | 10d | 2000-07-05 A | 2000-08-07 A | 0 210 | 100% | 2000-07-05 | 2000-07-18 |  |  |
| 218 219 | APPROVE SIDING | 10d | 2000-07-07 A | 2000-08-10 A | 0 218 | 100% | 2000-07-07 | 2000-07-20 |  |  |
| 220 221 | APPROVE PLANT ELECTRICAL LOAD CENTER | 10d | 2000-07-07 A | 2000-08-08 A | 0 220 | 100% | 2000-07-07 | 2000-07-20 |  |  |
| 222 223 | APPROVE POWER PANELS - PLANT | 10d | 2000-07-07 A | 2000-12-22 A | 0 222 | 100% | 2000-07-07 | 2000-07-20 |  |  |
| 0 225 | SUBMIT PLANT ELECTRICAL FIXTURES | 30d | 2000-07-14 A | 2000-08-25 A | 0 | 100% | 2000-07-14 | 2000-08-24 |  |  |
| 0 224 | SUBMIT EXTERIOR DOORS | 20d | 2000-07-20 A | 2000-07-21 A | 0 | 100% | 2000-07-20 | 2000-08-16 |  |  |
| 0 227 | SUBMIT PLANT HEATING AND VENTILATING FANS | 20d | 2000-07-20 A | 2000-08-18 A | 0 | 100% | 2000-07-20 | 2000-08-16 |  |  |
| 0 229 | SUBMIT BOILER | 20d | 2000-07-20 A | 2000-08-21 A | 0 | 100% | 2000-07-20 | 2000-08-16 |  |  |
| 224 225 | APPROVE EXTERIOR DOORS | 10d | 2000-07-21 A | 2000-08-08 A | 0 224 | 100% | 2000-07-21 | 2000-08-03 |  |  |
| 212 213 | APPROVE STRUCTURAL STEEL | 10d | 2000-07-28 A | 2000-08-08 A | 0 212 | 100% | 2000-07-28 | 2000-08-10 |  |  |
| 214 215 | APPROVE CRANE | 10d | 2000-07-28 A | 2000-08-08 A | 0 214 | 100% | 2000-07-28 | 2000-08-10 |  |  |
| 216 217 | APPROVE BAR JOISTS | 10d | 2000-07-28 A | 2000-08-08 A | 0 216 | 100% | 2000-07-28 | 2000-08-10 |  |  |

| ID | Activity | Duration | Start | Finish | Predecessors | Complete | Planned start | Planned finish | Total float | Free float |
| --- | --- | --- | --- | --- | --- | --- | --- | --- | --- | --- |
| 0 231 | SUBMIT OIL TANK | 20d | 2000-08-04 A | 2000-08-18 A | 0 | 100% | 2000-08-04 | 2000-08-31 |  |  |
| 233 234 | APPROVE PRECAST | 10d | 2000-08-04 A | 2000-08-18 A | 0 233 | 100% | 2000-08-04 | 2000-08-17 |  |  |
| 235 236 | APPROVE PACKAGED A/C | 10d | 2000-08-04 A | 2000-08-18 A | 0 235 | 100% | 2000-08-04 | 2000-08-17 |  |  |
| 211 16 | FAB/DEL FOUNDATION REBAR | 10d | 2000-08-07 A | 2000-08-08 A | 210 211 | 100% | 2000-08-07 | 2000-08-18 |  |  |
| 221 300 | FAB/DEL PLANT ELECTRICAL LOAD CENTER | 90d | 2000-08-08 A | 2000-12-15 A | 220 221 | 100% | 2000-08-08 | 2000-12-13 |  |  |
| 223 301 | FAB/DEL POWER PANELS - PLANT | 75d | 2000-08-08 A | 2001-03-07 A | 222 223 | 100% | 2000-08-08 | 2000-11-21 |  |  |
| 226 51 | FAB/DEL PLANT ELECTRICAL FIXTURES | 75d | 2000-08-15 A | 2000-12-14 A | 225 226 | 100% | 2000-08-15 | 2000-11-29 |  |  |
| 225 302 | FAB/DEL EXTERIOR DOORS | 80d | 2000-08-16 A | 2001-03-21 A | 0 225, 224 225 | 100% | 2000-08-16 | 2000-12-07 |  |  |
| 227 228 | APPROVE PLANT HEATING AND VENTILATING FANS | 10d | 2000-08-18 A | 2000-08-25 A | 0 227 | 100% | 2000-08-18 | 2000-08-31 |  |  |
| 231 232 | APPROVE OIL TANK | 10d | 2000-08-18 A | 2000-09-01 A | 0 231 | 100% | 2000-08-18 | 2000-08-31 |  |  |
| 236 60 | FAB/DEL PACKAGED A/C | 90d | 2000-08-18 A | 2001-02-23 A | 235 236 | 100% | 2000-08-18 | 2000-12-26 |  |  |
| 229 230 | APPROVE BOILER | 10d | 2000-08-21 A | 2000-09-01 A | 0 229 | 100% |  |  |  |  |
| 228 304 | FAB/DEL PLANT HEATING AND VENTILATING FANS | 75d | 2000-08-25 A | 2001-01-08 A | 227 228 | 100% | 2000-08-25 | 2000-12-11 |  |  |
| 230 306 | FAB/DEL BOILER | 60d | 2000-09-01 A | 2001-01-12 A | 229 230 | 100% | 2000-09-01 | 2000-11-27 |  |  |
| 232 305 | FAB/DEL OIL TANK | 50d | 2000-09-01 A | 2001-01-19 A | 231 232 | 100% | 2000-09-01 | 2000-11-10 |  |  |
| 21 22 | 21 22 | 0d | 2000-09-14 | 2000-09-13 | 18 21 |  | 2000-09-14 | 2000-09-14 | 8d |  |
| 32 33 | 32 33 | 0d | 2000-11-07 | 2000-11-06 | 31 32 |  | 2000-11-07 | 2000-11-07 | 0d |  |
| 36 37 | 36 37 | 0d | 2000-11-30 | 2000-11-29 | 35 36 |  | 2000-11-30 | 2000-11-30 | 0d |  |
| 37 300 | 37 300 | 0d | 2000-11-30 | 2000-11-29 | 35 37, 36 37 |  | 2000-11-30 | 2000-11-30 | 0d |  |
| 37 301 | 37 301 | 0d | 2000-11-30 | 2000-11-29 | 35 37, 36 37 |  | 2000-11-30 | 2000-11-30 | 12d | 0d |
| 37 302 | 37 302 | 0d | 2000-11-30 | 2000-11-29 | 35 37, 36 37 |  | 2000-11-30 | 2000-11-30 | 23d | 0d |
| 37 303 | 37 303 | 0d | 2000-11-30 | 2000-11-29 | 35 37, 36 37 |  | 2000-11-30 | 2000-11-30 | 13d | 0d |
| 37 304 | 37 304 | 0d | 2000-11-30 | 2000-11-29 | 35 37, 36 37 |  | 2000-11-30 | 2000-11-30 | 23d | 0d |
| 37 305 | 37 305 | 0d | 2000-11-30 | 2000-11-29 | 35 37, 36 37 |  | 2000-11-30 | 2000-11-30 | 70d | 0d |
| 37 306 | 37 306 | 0d | 2000-11-30 | 2000-11-29 | 35 37, 36 37 |  | 2000-11-30 | 2000-11-30 | 43d | 0d |
| 37 307 | 37 307 | 0d | 2000-11-30 | 2000-11-29 | 35 37, 36 37 |  | 2000-11-30 | 2000-11-30 | 33d | 0d |
| 37 308 | 37 308 | 0d | 2000-11-30 | 2000-11-29 | 35 37, 36 37 |  | 2000-11-30 | 2000-11-30 | 73d | 0d |
| 90 58 | 90 58 | 0d | 2000-12-07 | 2000-12-06 | 37 90 |  | 2000-12-07 | 2000-12-07 | 73d |  |
| 92 58 | 92 58 | 0d | 2000-12-14 | 2000-12-13 | 37 92 |  | 2000-12-14 | 2000-12-14 | 68d |  |
| 93 80 | 93 80 | 0d | 2000-12-29 | 2000-12-28 | 37 93 |  | 2000-12-29 | 2000-12-29 | 68d |  |
| 62 63 | 62 63 | 0d | 2001-01-02 | 2000-12-29 | 61 62 |  | 2001-01-02 | 2001-01-02 | 22d | 0d |
| 63 68 | 63 68 | 0d | 2001-01-02 | 2000-12-29 | 61 63, 62 63 |  | 2001-01-02 | 2001-01-02 | 22d | 14d |
| 44 45 | 44 45 | 0d | 2001-01-08 | 2001-01-05 | 42 44 |  | 2001-01-08 | 2001-01-08 | 37d | 12d |
| 44 46 | 44 46 | 0d | 2001-01-08 | 2001-01-05 | 42 44 |  | 2001-01-08 | 2001-01-08 | 13d | 0d |
| 66 67 | 66 67 | 0d | 2001-01-15 | 2001-01-12 | 65 66 |  | 2001-01-15 | 2001-01-15 | 8d | 0d |
| 49 45 | 49 45 | 0d | 2001-01-24 | 2001-01-23 | 43 49 |  | 2001-01-24 | 2001-01-24 | 25d | 0d |
| 74 76 | 74 76 | 0d | 2001-01-29 | 2001-01-26 | 66 74 |  | 2001-01-29 | 2001-01-29 | 39d | 0d |
| 70 77 | 70 77 | 0d | 2001-02-12 | 2001-02-09 | 69 70 |  | 2001-02-12 | 2001-02-12 | 23d | 0d |
| 72 73 | 72 73 | 0d | 2001-03-12 | 2001-03-09 | 71 72 |  | 2001-03-12 | 2001-03-12 | 13d | 0d |
| 72 78 | 72 78 | 0d | 2001-03-12 | 2001-03-09 | 71 72 |  | 2001-03-12 | 2001-03-12 | 8d | 0d |
| 80 | END OF NETWORK | 1d | 2001-04-05 A | 2001-04-05 A | 37 80, 58 80, 63 80, 71 80, 72 80, 73 80, 78 80, 79 80, 93 80, 94 80 | 100% |  |  |  |  |

# JOHN DOE PROJECT PDM VERSION

Schedule from Primavera P6, 2000-06-05 to 2001-04-03, data date 2000-06-05, costs in USD.

## Calendars

- DOE0 - 1: Mon-Fri 08:00-12:00, 13:00-17:00; Sat-Sun off. Exceptions (off unless hours are given): 2000-07-04, 2000-09-04, 2000-11-23, 2000-12-25, 2001-01-01.

## Resources

| Resource | Group |
| --- | --- |
| COST | labor |
| SV | labor |
| OP | labor |
| Plumbers | labor |
| BM | labor |
| Carpenters | labor |
| LB | labor |
| Electricians | labor |
| Iron Workers | labor |
| PF | labor |
| ST | labor |
| SM | labor |
| PA | labor |
| IN | labor |
| TL | labor |
| MA | labor |
| Roofers | labor |
| GZ | labor |

## Schedule

| ID | Activity | Type | Duration | Start | Finish | Predecessors | Total float | Free float | Resources | Cost |
| --- | --- | --- | --- | --- | --- | --- | --- | --- | --- | --- |
| 0 | START MILESTONE | milestone | 0d | 2000-06-05 | 2000-06-05 |  | 0d |  |  |  |
| 100 | CLEAR SITE |  | 3d | 2000-06-05 | 2000-06-07 | 0 | 0d |  | COST; OP [120 h] | 28,000 |
| 110 | SUBMIT FOUNDATION REBAR |  | 10d | 2000-06-05 | 2000-06-16 | 0 | 20d | 0d |  |  |
| 112 | SUBMIT STRUCTURAL STEEL |  | 20d | 2000-06-05 | 2000-06-30 | 0 | 38d | 0d |  |  |
| 114 | SUBMIT CRANE |  | 20d | 2000-06-05 | 2000-06-30 | 0 | 23d | 0d |  |  |
| 116 | SUBMIT BAR JOISTS |  | 20d | 2000-06-05 | 2000-06-30 | 0 | 48d | 0d |  |  |
| 118 | SUBMIT SIDING |  | 20d | 2000-06-05 | 2000-06-30 | 0 | 44d | 0d |  |  |
| 120 | SUBMIT PLANT ELECTRICAL LOAD CENTER |  | 20d | 2000-06-05 | 2000-06-30 | 0 | 4d | 0d |  |  |
| 122 | SUBMIT POWER PANELS - PLANT |  | 20d | 2000-06-05 | 2000-06-30 | 0 | 31d | 0d |  |  |
| 124 | SUBMIT EXTERIOR DOORS |  | 20d | 2000-06-05 | 2000-06-30 | 0 | 6d | 0d |  |  |
| 125 | SUBMIT PLANT ELECTRICAL FIXTURES |  | 30d | 2000-06-05 | 2000-07-17 | 0 | 6d | 0d |  |  |
| 127 | SUBMIT PLANT HEATING AND VENTILATING FANS |  | 20d | 2000-06-05 | 2000-06-30 | 0 | 42d | 0d |  |  |
| 129 | SUBMIT BOILER |  | 20d | 2000-06-05 | 2000-06-30 | 0 | 77d | 0d |  |  |
| 131 | SUBMIT OIL TANK |  | 20d | 2000-06-05 | 2000-06-30 | 0 | 114d | 0d |  |  |
| 133 | SUBMIT PRECAST |  | 40d | 2000-06-05 | 2000-07-31 | 0 | 48d | 0d |  |  |
| 135 | SUBMIT PACKAGED A/C |  | 30d | 2000-06-05 | 2000-07-17 | 0 | 8d | 0d |  |  |
| 1 | SURVEY AND LAYOUT |  | 2d | 2000-06-08 | 2000-06-09 | 100 | 0d |  | COST; SV [48 h] | 2,500 |
| 2 | ROUGH GRADE |  | 2d | 2000-06-12 | 2000-06-13 | 1 | 0d |  | COST; OP [48 h] | 10,000 |
| 3 | DRILL WELL |  | 15d | 2000-06-14 | 2000-07-05 | 2 | 0d |  | COST; Plumbers [240 h] | 10,000 |
| 401 | WATER TANK FOUNDATIONS |  | 4d | 2000-06-14 | 2000-06-19 | 2 | 1d | 0d | COST; Carpenters [128 h]; LB [64 h] | 5,000 |
| 402 | EXCAVATE FOR SEWER |  | 10d | 2000-06-14 | 2000-06-27 | 2 | 4d | 0d | COST; OP [400 h] | 21,500 |
| 403 | EXCAVATE ELECTRIC MANHOLES |  | 1d | 2000-06-14 | 2000-06-14 | 2 | 13d | 0d | COST; OP [16 h] | 1,000 |
| 404 | OVERHEAD POLE LINE |  | 6d | 2000-06-14 | 2000-06-21 | 2 | 16d | 12d | COST; Electricians [192 h] | 30,000 |
| 10 | INSTALL ELECTRICAL MANHOLES |  | 5d | 2000-06-15 | 2000-06-21 | 403 | 13d | 9d | COST; Carpenters [160 h]; LB [80 h] | 6,500 |
| 210 | APPROVE FOUNDATION REBAR |  | 10d | 2000-06-19 | 2000-06-30 | 110 | 20d | 0d |  |  |
| 6 | ERECT WATER TANK |  | 10d | 2000-06-20 | 2000-07-03 | 401 | 1d | 0d | COST; BM [640 h] | 225,000 |
| 9 | INSTALL SEWER AND BACKFILL |  | 5d | 2000-06-28 | 2000-07-05 | 402 | 4d | 0d | COST; Plumbers [240 h] | 65,000 |
| 211 | FAB/DEL FOUNDATION REBAR |  | 10d | 2000-07-03 | 2000-07-17 | 210 | 20d |  |  |  |
| 212 | APPROVE STRUCTURAL STEEL |  | 10d | 2000-07-03 | 2000-07-17 | 112 | 38d | 0d |  |  |
| 214 | APPROVE CRANE |  | 10d | 2000-07-03 | 2000-07-17 | 114 | 23d | 0d |  |  |
| 216 | APPROVE BAR JOISTS |  | 10d | 2000-07-03 | 2000-07-17 | 116 | 48d | 0d |  |  |
| 218 | APPROVE SIDING |  | 10d | 2000-07-03 | 2000-07-17 | 118 | 44d | 0d |  |  |
| 220 | APPROVE PLANT ELECTRICAL LOAD CENTER |  | 10d | 2000-07-03 | 2000-07-17 | 120 | 4d | 0d |  |  |
| 222 | APPROVE POWER PANELS - PLANT |  | 10d | 2000-07-03 | 2000-07-17 | 122 | 31d | 0d |  |  |
| 224 | APPROVE EXTERIOR DOORS |  | 10d | 2000-07-03 | 2000-07-17 | 124 | 6d | 0d | COST | 60,000 |
| 227 | APPROVE PLANT HEATING AND VENTILATING FANS |  | 10d | 2000-07-03 | 2000-07-17 | 127 | 42d | 0d |  |  |
| 229 | APPROVE BOILER |  | 10d | 2000-07-03 | 2000-07-17 | 129 | 77d | 0d |  |  |
| 231 | APPROVE OIL TANK |  | 10d | 2000-07-03 | 2000-07-17 | 131 | 114d | 0d |  |  |
| 7 | TANK PIPING & VALVES |  | 10d | 2000-07-05 | 2000-07-18 | 6 | 1d |  | COST; BM [320 h] | 40,000 |
| 4 | INSTALL WELL PUMP |  | 2d | 2000-07-06 | 2000-07-07 | 3 | 0d |  | COST; Plumbers [32 h] | 11,250 |
| 11 | INSTALL ELECTRICAL DUCT BANK |  | 3d | 2000-07-06 | 2000-07-10 | 9, 10 | 4d | 0d | COST; Electricians [144 h] | 7,500 |
| 5 | UNDERGROUND WATER PIPING |  | 8d | 2000-07-10 | 2000-07-19 | 4 | 0d |  | COST; Plumbers [128 h] | 18,000 |
| 12 | PULL IN FEEDER |  | 5d | 2000-07-11 | 2000-07-17 | 11, 404 | 4d |  | COST; Electricians [160 h] | 6,000 |
| 213 | FAB/DEL STRUCTURAL STEEL |  | 40d | 2000-07-18 | 2000-09-12 | 212 | 38d | 0d | COST | 550,000 |
| 215 | FAB/DEL CRANE |  | 50d | 2000-07-18 | 2000-09-26 | 214 | 23d |  | COST | 180,000 |
| 217 | FAB/DEL BAR JOISTS |  | 30d | 2000-07-18 | 2000-08-28 | 216 | 48d |  | COST | 60,000 |
| 219 | FAB/DEL SIDING |  | 40d | 2000-07-18 | 2000-09-12 | 218 | 44d |  | COST | 300,000 |
| 221 | FAB/DEL PLANT ELECTRICAL LOAD CENTER |  | 90d | 2000-07-18 | 2000-11-21 | 220 | 4d |  |  |  |
| 223 | FAB/DEL POWER PANELS - PLANT |  | 75d | 2000-07-18 | 2000-10-31 | 222 | 31d | 19d |  |  |
| 225 | FAB/DEL EXTERIOR DOORS |  | 80d | 2000-07-18 | 2000-11-07 | 125, 224 | 6d | 0d | COST | 60,000 |
| 228 | FAB/DEL PLANT HEATING AND VENTILATING FANS |  | 75d | 2000-07-18 | 2000-10-31 | 227 | 42d | 19d |  |  |
| 230 | FAB/DEL BOILER |  | 60d | 2000-07-18 | 2000-10-10 | 229 | 77d | 34d |  |  |
| 232 | FAB/DEL OIL TANK |  | 50d | 2000-07-18 | 2000-09-26 | 231 | 114d | 44d |  |  |
| 235 | APPROVE PACKAGED A/C |  | 10d | 2000-07-18 | 2000-07-31 | 135 | 8d | 0d |  |  |
| 8 | CONNECT WATER PIPING |  | 2d | 2000-07-20 | 2000-07-21 | 5, 7 | 0d |  | COST; BM [64 h] | 2,000 |
| 13 | BUILDING LAYOUT |  | 1d | 2000-07-24 | 2000-07-24 | 8, 12 | 0d |  | COST; SV [24 h] | 4,000 |
| 14 | DRIVE AND POUR PILES |  | 10d | 2000-07-25 | 2000-08-07 | 13 | 0d |  | COST; OP [160 h]; Carpenters [160 h]; LB [160 h] | 70,000 |
| 405 | EXCAVATE FOR OFFICE BUILDING |  | 3d | 2000-07-25 | 2000-07-27 | 13 | 70d | 32d | COST; OP [120 h] | 27,000 |
| 233 | APPROVE PRECAST |  | 10d | 2000-08-01 | 2000-08-14 | 133 | 48d | 0d |  |  |
| 236 | FAB/DEL PACKAGED A/C |  | 90d | 2000-08-01 | 2000-12-06 | 235 | 8d | 0d |  |  |
| 15 | EXCAVATE PLANT WAREHOUSE |  | 5d | 2000-08-08 | 2000-08-14 | 14 | 0d |  | COST; OP [200 h] | 86,000 |
| 16 | POUR PILE CAPS P-W |  | 5d | 2000-08-15 | 2000-08-21 | 15, 211 | 0d |  | COST; Carpenters [160 h]; LB [800 h] | 50,000 |
| 234 | FAB/DEL PRECAST |  | 30d | 2000-08-15 | 2000-09-26 | 233 | 48d | 10d | COST | 70,000 |
| 17 | FORM AND POUR GRADE BEAMS P-W |  | 10d | 2000-08-22 | 2000-09-05 | 16 | 0d |  | COST; Carpenters [160 h]; LB [160 h] | 70,000 |
| 18 | BACKFILL AND COMPACT P-W |  | 3d | 2000-09-06 | 2000-09-08 | 17 | 0d |  | COST; OP [120 h] | 9,000 |
| 406 | FORM AND POUR RAILROAD LOADING DOCK P-W |  | 5d | 2000-09-06 | 2000-09-12 | 17 | 8d |  | COST; Carpenters [160 h]; LB [80 h] | 15,000 |
| 407 | FORM AND POUR TRUCK LOADING DOCK P-W |  | 5d | 2000-09-06 | 2000-09-12 | 17 | 8d |  | COST; Carpenters [160 h]; LB [80 h] | 15,000 |
| 19 | UNDERSLAB PLUMBING P-W |  | 5d | 2000-09-11 | 2000-09-15 | 18 | 0d |  | COST; Plumbers [160 h] | 12,000 |
| 23 | SPREAD FOOTINGS OFFICE |  | 4d | 2000-09-13 | 2000-09-18 | 213, 405 | 38d | 0d | COST; Carpenters [128 h]; LB [64 h] | 17,500 |
| 20 | UNDERSLAB CONDUIT P-W |  | 5d | 2000-09-18 | 2000-09-22 | 19 | 0d |  | COST; Electricians [240 h] | 7,500 |

| ID | Activity | Duration | Start | Finish | Predecessors | Total float | Free float | Resources | Cost |
| --- | --- | --- | --- | --- | --- | --- | --- | --- | --- |
| 24 | FORM AND POUR GRADE BEAMS OFFICE | 6d | 2000-09-19 | 2000-09-26 | 23 | 38d | 0d | COST; Carpenters [192 h]; LB [96 h] | 21,000 |
| 22 | FORM AND POUR SLABS P-W | 10d | 2000-09-25 | 2000-10-06 | 20, 406, 407 | 0d |  | COST; Carpenters [320 h]; LB [160 h] | 225,000 |
| 25 | BACKFILL AND COMPACT OFFICE | 1d | 2000-09-27 | 2000-09-27 | 24 | 38d | 0d | COST; OP [40 h] | 1,800 |
| 26 | UNDERSLAB PLUMBING OFFICE | 3d | 2000-09-28 | 2000-10-02 | 25 | 38d | 0d | COST; Plumbers [96 h] | 9,000 |
| 27 | UNDERSLAB CONDUIT OFFICE | 3d | 2000-10-03 | 2000-10-05 | 26 | 38d | 0d | COST; Carpenters [96 h]; LB [48 h] | 5,000 |
| 28 | FORM AND POUR SLABS OFFICE | 3d | 2000-10-06 | 2000-10-10 | 27 | 38d | 0d | COST; Carpenters [96 h]; LB [48 h] | 18,000 |
| 29 | ERECT STRUCTURAL STEEL P-W | 10d | 2000-10-09 | 2000-10-20 | 22 | 0d |  | COST; OP [160 h]; Iron Workers [480 h] | 50,000 |
| 99 | ERECT PRECAST STRUCTURE | 5d | 2000-10-11 | 2000-10-17 | 28, 234 | 38d | 0d | COST; OP [40 h]; Carpenters [80 h]; LB [80 h] | 20,000 |
| 59 | ERECT PRECAST ROOF OFFICE | 5d | 2000-10-18 | 2000-10-24 | 99 | 38d | 0d | COST; OP [40 h]; Carpenters [80 h]; LB [80 h] | 30,000 |
| 30 | PLUMB AND BOLT STEEL P-W | 5d | 2000-10-23 | 2000-10-27 | 29 | 0d |  | COST; OP [80 h]; Iron Workers [240 h] | 15,000 |
| 416 | INSTALL PACKAGE AIR CONDITIONING | 5d | 2000-10-25 | 2000-10-31 | 59 | 98d | 59d | COST; ST [80 h] | 40,000 |
| 31 | ERECT CRANEWAY AND CRANE P-W | 5d | 2000-10-30 | 2000-11-03 | 30, 215 | 0d |  | COST; Iron Workers [160 h] | 20,000 |
| 408 | ERECT MONORAIL TRACK P-W | 3d | 2000-10-30 | 2000-11-01 | 30 | 2d |  | COST; Iron Workers [96 h] | 10,000 |
| 33 | ERECT BAR JOISTS P-W | 3d | 2000-11-06 | 2000-11-08 | 31, 217, 408 | 0d |  | COST; OP [48 h]; Iron Workers [144 h] | 15,000 |
| 226 | FAB/DEL PLANT ELECTRICAL FIXTURES | 75d | 2000-11-08 | 2001-02-23 | 225 | 6d | 0d |  |  |
| 34 | ERECT ROOF PLANKS P-W | 3d | 2000-11-09 | 2000-11-13 | 33 | 0d |  | COST; LB [48 h]; OP [48 h]; Carpenters [48 h] | 15,000 |
| 35 | ERECT SIDING P-W | 10d | 2000-11-14 | 2000-11-28 | 34, 219 | 0d |  | COST; OP [160 h]; Iron Workers [480 h] | 75,000 |
| 409 | BUILT-UP ROOFING P-W | 5d | 2000-11-14 | 2000-11-20 | 34 | 5d |  | COST; Roofers [320 h] | 175,000 |
| 37 | PERIMETER FENCE | 10d | 2000-11-29 | 2000-12-12 | 35, 409 | 78d |  | COST; LB [480 h] | 25,000 |
| 300 | SET ELECTRICAL LOAD CENTER | 2d | 2000-11-29 | 2000-11-30 | 35, 221, 409 | 0d |  | COST; Electricians [64 h] | 30,500 |
| 301 | INSTALL POWER PANEL BACKING BOXES | 10d | 2000-11-29 | 2000-12-12 | 35, 223, 409 | 12d |  | COST; Electricians [480 h] | 18,000 |
| 302 | EXTERIOR DOORS P-W | 5d | 2000-11-29 | 2000-12-05 | 35, 409 | 23d | 10d | COST; Carpenters [80 h]; LB [80 h] | 30,000 |
| 303 | MASONRY PARTITIONS | 10d | 2000-11-29 | 2000-12-12 | 35, 225, 409 | 13d | 0d | COST; MA [800 h] | 80,000 |
| 304 | INSTALL HEATING AND VENTILATING UNITS | 15d | 2000-11-29 | 2000-12-19 | 35, 228, 409 | 23d | 10d | COST; ST [960 h] | 120,000 |
| 305 | INSTALL FUEL OIL TANK | 3d | 2000-11-29 | 2000-12-01 | 35, 232, 409 | 70d | 37d | COST; ST [96 h] | 15,000 |
| 306 | ERECT BOILERS AND AUXILIARIES | 25d | 2000-11-29 | 2001-01-04 | 35, 230, 409 | 43d | 0d | COST; ST [800 h] | 25,000 |
| 307 | FABRICATE PIPING SYSTEMS | 30d | 2000-11-29 | 2001-01-11 | 35, 409 | 33d | 0d | COST | 60,000 |
| 308 | INSTALL MONORAIL | 5d | 2000-11-29 | 2000-12-05 | 35, 409 | 78d | 73d | COST; Iron Workers [160 h] | 25,000 |
| 410 | PAVE PARKING AREA | 5d | 2000-11-29 | 2000-12-05 | 35, 409 | 73d |  | COST; OP [160 h]; LB [240 h] | 35,000 |
| 411 | GRADE AND BALLAST RAILROAD SIDING | 5d | 2000-11-29 | 2000-12-05 | 35, 409 | 68d | 0d | COST; OP [80 h]; LB [240 h] | 20,000 |
| 412 | ACCESS ROAD | 10d | 2000-11-29 | 2000-12-12 | 35, 409 | 68d |  | COST; OP [320 h]; LB [480 h] | 25,000 |
| 413 | AREA LIGHTING | 20d | 2000-11-29 | 2000-12-27 | 35, 409 | 68d |  | COST; Electricians [640 h] | 33,000 |
| 38 | INSTALL POWER CONDUIT P-W | 20d | 2000-12-01 | 2000-12-29 | 300 | 0d |  | COST; Electricians [960 h] | 21,000 |
| 91 | INSTALL RAILROAD SIDING | 10d | 2000-12-06 | 2000-12-19 | 411 | 68d | 63d | COST; OP [160 h]; LB [480 h] | 50,000 |
| 60 | EXTERIOR MASONRY OFFICE | 10d | 2000-12-07 | 2000-12-20 | 59, 236 | 8d | 0d | COST; MA [800 h] | 380,000 |
| 39 | FRAME CEILING P-W | 5d | 2000-12-13 | 2000-12-19 | 303 | 13d | 0d | COST; Carpenters [240 h]; LB [80 h] | 25,000 |
| 42 | DRYWALL PARTITIONS P-W | 10d | 2000-12-20 | 2001-01-04 | 39, 302 | 13d | 0d | COST; Carpenters [480 h]; LB [160 h] | 35,000 |
| 61 | EXTERIOR DOORS OFFICE | 5d | 2000-12-21 | 2000-12-28 | 60 | 22d | 0d | COST; Carpenters [40 h]; LB [40 h] | 3,600 |
| 417 | PLACE SINGLE-PLY ROOFING OFFICE | 5d | 2000-12-21 | 2000-12-28 | 60 | 62d | 0d | COST; Roofers [320 h] | 32,000 |
| 418 | INSTALL PIPING OFFICE | 10d | 2000-12-21 | 2001-01-05 | 60 | 8d | 0d | COST; PF [320 h] | 9,000 |
| 419 | INSTALL BACKING BOXES | 4d | 2000-12-21 | 2000-12-27 | 60 | 8d | 0d | COST; Electricians [128 h] | 4,000 |
| 420 | GLAZE OFFICE | 5d | 2000-12-21 | 2000-12-28 | 60 | 22d | 14d | COST; GZ [320 h] | 12,000 |
| 421 | DUCTWORK OFFICE | 15d | 2000-12-21 | 2001-01-12 | 60 | 42d | 19d | COST; SM [480 h] | 16,000 |
| 65 | INSTALL CONDUIT OFFICE | 10d | 2000-12-28 | 2001-01-11 | 419 | 8d | 0d | COST; Electricians [480 h] | 9,000 |
| 63 | PAINT EXTERIOR OFFICE | 5d | 2000-12-29 | 2001-01-05 | 61, 417 | 62d |  | COST; PA [320 h] | 6,000 |
| 43 | INSTALL BRANCH CONDUIT P-W | 15d | 2001-01-02 | 2001-01-22 | 38, 301 | 0d |  | COST; Electricians [720 h] | 29,000 |
| 41 | PREOPERATIONAL CHECK | 5d | 2001-01-05 | 2001-01-11 | 306 | 43d | 10d | COST; ST [80 h] | 2,000 |
| 44 | HANG INTERIOR DOORS P-W | 10d | 2001-01-05 | 2001-01-18 | 42 | 43d |  | COST; Carpenters [160 h]; LB [160 h] | 10,000 |
| 46 | INSTALL DUCTWORK P-W | 25d | 2001-01-05 | 2001-02-08 | 42, 304 | 13d | 0d | COST; SM [800 h] | 25,000 |
| 424 | CERAMIC TILE P-W | 10d | 2001-01-05 | 2001-01-18 | 42 | 18d | 0d | TL [480 h]; COST | 10,000 |
| 64 | TEST PIPING OFFICE | 4d | 2001-01-08 | 2001-01-11 | 418 | 8d | 0d | COST; PF [64 h] | 1,000 |
| 40 | TEST PIPING SYSTEMS P-W | 10d | 2001-01-12 | 2001-01-25 | 307 | 33d | 0d | COST; PF [320 h] | 5,000 |
| 66 | PULL WIRE OFFICE | 10d | 2001-01-12 | 2001-01-25 | 65 | 28d | 0d | COST; Electricians [480 h] | 10,000 |
| 67 | METAL STUDS OFFICE | 5d | 2001-01-12 | 2001-01-18 | 64, 65 | 8d | 0d | COST; Carpenters [400 h]; LB [400 h] | 5,000 |
| 48 | PAINT ROOMS P-W | 5d | 2001-01-19 | 2001-01-25 | 424 | 18d | 0d | COST; PA [400 h] | 15,000 |
| 68 | DRYWALL | 5d | 2001-01-19 | 2001-01-25 | 61, 67, 420 | 8d | 0d | COST; Carpenters [200 h]; LB [200 h] | 5,000 |
| 45 | ROOM OUTLETS P-W | 5d | 2001-01-23 | 2001-01-29 | 42, 43 | 25d | 19d | COST; Electricians [240 h] | 16,500 |
| 49 | PULL WIRE P-W | 15d | 2001-01-23 | 2001-02-12 | 43 | 0d |  | COST; Electricians [720 h] | 38,000 |
| 47 | LIGHT OFF BOILER AND TEST | 5d | 2001-01-26 | 2001-02-01 | 40, 41, 305 | 33d |  | COST; ST [80 h] | 1,500 |
| 53 | FLOOR TILE P-W | 10d | 2001-01-26 | 2001-02-08 | 48 | 18d | 0d | COST; TL [640 h] | 20,000 |
| 69 | DRYWALL | 10d | 2001-01-26 | 2001-02-08 | 68 | 8d | 0d | COST; Carpenters [400 h]; LB [400 h] | 10,000 |
| 74 | INSTALL PANEL INTERNALS OFFICE | 5d | 2001-01-26 | 2001-02-01 | 66 | 28d | 0d | COST; Electricians [240 h] | 5,000 |
| 76 | A/C ELECTRICAL CONNECTIONS | 4d | 2001-01-26 | 2001-01-31 | 66, 416 | 39d | 11d | COST; Electricians [128 h] | 2,000 |
| 414 | INSTALL PLUMBING FIXTURES P-W | 10d | 2001-01-26 | 2001-02-08 | 48 | 28d |  | COST; Plumbers [320 h] | 20,000 |
| 422 | CERAMIC TILE OFFICE | 10d | 2001-01-26 | 2001-02-08 | 68 | 33d | 20d | COST; TL [480 h] | 9,000 |
| 75 | TERMINATE WIRES OFFICE | 10d | 2001-02-02 | 2001-02-15 | 74 | 28d | 0d | COST; Electricians [480 h] | 7,500 |
| 52 | INSULATE HEATING AND VENTILATING SYSTEM P-W | 15d | 2001-02-09 | 2001-03-01 | 46 | 13d |  | COST; IN [720 h] | 10,000 |
| 57 | INSTALL FURNISHINGS P-W | 10d | 2001-02-09 | 2001-02-22 | 53 | 18d |  | COST; LB [480 h] | 30,000 |
| 70 | WOOD TRIM OFFICE | 10d | 2001-02-09 | 2001-02-22 | 69 | 8d | 0d | COST; Carpenters [320 h] | 12,000 |
| 77 | INSTALL CEILING GRID OFFICE | 5d | 2001-02-09 | 2001-02-15 | 69, 421 | 23d | 15d | COST; Carpenters [160 h]; LB [160 h] | 10,000 |

| ID | Activity | Type | Duration | Start | Finish | Predecessors | Planned start | Planned finish | Total float | Free float | Resources | Cost |
| --- | --- | --- | --- | --- | --- | --- | --- | --- | --- | --- | --- | --- |
| 50 | INSTALL PANEL INTERNALS P-W |  | 5d | 2001-02-13 | 2001-02-19 | 49 |  |  | 0d |  | COST; Electricians [160 h] | 7,500 |
| 79 | RING OUT |  | 5d | 2001-02-16 | 2001-02-22 | 75, 76 |  |  | 28d |  | COST; Electricians [80 h] | 2,500 |
| 54 | TERMINATE WIRE P-W |  | 10d | 2001-02-20 | 2001-03-05 | 50 |  |  | 0d |  | COST; Electricians [320 h] | 7,500 |
| 71 | PAINT INTERIOR OFFICE |  | 10d | 2001-02-23 | 2001-03-08 | 70 |  |  | 8d | 0d | COST; PA [800 h] | 16,000 |
| 423 | HANG DOORS OFFICE |  | 5d | 2001-02-23 | 2001-03-01 | 70 |  |  | 23d |  | COST; Carpenters [160 h]; LB [160 h] | 10,000 |
| 51 | INSTALL ELECTRICAL FIXTURES |  | 10d | 2001-02-26 | 2001-03-09 | 45, 226 |  |  | 6d |  | COST; Electricians [480 h] | 31,000 |
| 55 | RING OUT P-W |  | 10d | 2001-03-06 | 2001-03-19 | 54 |  |  | 0d |  | COST; Electricians [320 h] | 5,000 |
| 72 | FLOOR TILE OFFICE |  | 10d | 2001-03-09 | 2001-03-22 | 71 |  |  | 8d |  | COST; TL [480 h] | 18,000 |
| 73 | TOILET FIXTURES OFFICE |  | 5d | 2001-03-09 | 2001-03-15 | 71, 422 |  |  | 13d |  | COST; Plumbers [160 h] | 10,000 |
| 78 | ACOUSTIC TILES OFFICE |  | 10d | 2001-03-09 | 2001-03-22 | 71, 77 |  |  | 8d |  | COST; Carpenters [160 h]; LB [160 h] | 20,000 |
| 56 | ENERGIZE POWER |  | 1d | 2001-03-20 | 2001-03-20 | 51, 55 |  |  | 0d |  | COST; Electricians [16 h] | 2,000 |
| 58 | ERECT FLAGPOLE |  | 5d | 2001-03-21 | 2001-03-27 | 44, 47, 52, 56, 57, 91, 308, 410, 412, 414 |  |  | 5d |  | COST; LB [80 h] | 1,500 |
| 415 | FINE GRADE |  | 5d | 2001-03-21 | 2001-03-27 | 44, 47, 52, 56, 57, 410, 412, 414 |  |  | 0d |  | COST; OP [80 h] | 5,000 |
| 94 | SEED AND PLANT |  | 5d | 2001-03-28 | 2001-04-03 | 415 |  |  | 0d |  | COST; LB [240 h] | 20,000 |
| 80 | END OF NETWORK MILESTONE | milestone | 0d | 2001-04-03 | 2001-04-03 | 37, 58, 63, 72, 73, 78, 79, 94, 413, 423 | 2001-04-04 | 2001-04-04 | 0d |  |  |  |

# JOHN DOE PROJECT ADM-PDM DEMO

Schedule from Primavera P6, 2000-06-05 to 2000-11-30, data date 2000-06-05, costs in USD.

## Calendars

- JDOE - 1: Mon-Fri 08:00-12:00, 13:00-17:00; Sat-Sun off. Exceptions (off unless hours are given): 2000-07-04, 2000-09-04, 2000-11-23.

## Resources

| Resource | Group |
| --- | --- |
| COST | labor |
| OP | labor |
| SV | labor |
| Plumbers | labor |
| Carpenters | labor |
| LB | labor |
| Electricians | labor |
| BM | labor |
| Iron Workers | labor |
| Roofers | labor |

## Schedule

| ID | Activity | Duration | Start | Finish | Predecessors | Planned start | Planned finish | Total float | Free float | Resources | Cost | FULL NETWORK ID |
| --- | --- | --- | --- | --- | --- | --- | --- | --- | --- | --- | --- | --- |
| 0 | START OF NETWORK | 1d | 2000-06-05 | 2000-06-05 |  |  |  | 0d |  |  |  | 0 |
| 28 99 | 28 99 | 1d | 2000-06-05 | 2000-06-05 |  |  |  | 0d |  |  |  |  |
| 0 1 | CLEAR SITE | 3d | 2000-06-06 | 2000-06-08 | 0 |  |  | 0d |  | COST; OP [120 h] | 28,000 | 0 1 |
| 1 2 | SURVEY AND LAYOUT | 2d | 2000-06-09 | 2000-06-12 | 0 1 |  |  | 0d |  | COST; SV [48 h] | 2,500 | 1 2 |
| 2 3 | ROUGH GRADE | 2d | 2000-06-13 | 2000-06-14 | 1 2 |  |  | 0d |  | COST; OP [48 h] | 10,000 | 2 3 |
| 3 4 | DRILL WELL | 15d | 2000-06-15 | 2000-07-06 | 2 3 |  |  | 0d |  | COST; Plumbers [240 h] | 10,000 | 3 4 |
| 3 6 | WATER TANK FOUNDATIONS | 4d | 2000-06-15 | 2000-06-20 | 2 3 |  |  | 1d | 0d | COST; Carpenters [128 h]; LB [64 h] | 5,000 | 3 6 |
| 3 9 | EXCAVATE FOR SEWER | 10d | 2000-06-15 | 2000-06-28 | 2 3 |  |  | 4d | 0d | COST; OP [400 h] | 21,500 | 3 9 |
| 3 10 | EXCAVATE ELECTRIC MANHOLES | 1d | 2000-06-15 | 2000-06-15 | 2 3 |  |  | 13d | 0d | COST; OP [16 h] | 1,000 | 3 10 |
| 3 12 | OVERHEAD POLE LINE | 6d | 2000-06-15 | 2000-06-22 | 2 3 |  |  | 16d | 12d | COST; Electricians [192 h] | 30,000 | 3 12 |
| 10 11 | INSTALL ELECTRICAL MANHOLES | 5d | 2000-06-16 | 2000-06-22 | 3 10 |  |  | 13d | 9d | COST; Carpenters [160 h]; LB [80 h] | 6,500 | 10 11 |
| 6 7 | ERECT WATER TANK | 10d | 2000-06-21 | 2000-07-05 | 3 6 |  |  | 1d | 0d | COST; BM [640 h] | 225,000 | 6 7 |
| 9 11 | INSTALL SEWER AND BACKFILL | 5d | 2000-06-29 | 2000-07-06 | 3 9 |  |  | 4d | 0d | COST; Plumbers [240 h] | 65,000 | 9 11 |
| 7 8 | TANK PIPING & VALVES | 10d | 2000-07-06 | 2000-07-19 | 6 7 |  |  | 1d |  | COST; BM [320 h] | 40,000 | 7 8 |
| 4 5 | INSTALL WELL PUMP | 2d | 2000-07-07 | 2000-07-10 | 3 4 |  |  | 0d |  | COST; Plumbers [32 h] | 11,250 | 4 5 |
| 11 12 | INSTALL ELECTRICAL DUCT BANK | 3d | 2000-07-07 | 2000-07-11 | 9 11, 10 11 |  |  | 4d | 0d | COST; Electricians [144 h] | 7,500 | 11 12 |
| 5 8 | UNDERGROUND WATER PIPING | 8d | 2000-07-11 | 2000-07-20 | 4 5 |  |  | 0d |  | COST; Plumbers [128 h] | 18,000 | 5 8 |
| 12 13 | PULL IN FEEDER | 5d | 2000-07-12 | 2000-07-18 | 3 12, 11 12 |  |  | 4d |  | COST; Electricians [160 h] | 6,000 | 12 13 |
| 8 13 | CONNECT WATER PIPING | 2d | 2000-07-21 | 2000-07-24 | 5 8, 7 8 |  |  | 0d |  | COST; BM [64 h] | 2,000 | 8 13 |
| 13 14 | BUILDING LAYOUT | 1d | 2000-07-25 | 2000-07-25 | 8 13, 12 13 |  |  | 0d |  | COST; SV [24 h] | 4,000 | 13 14 |
| 14 15 | DRIVE AND POUR PILES | 10d | 2000-07-26 | 2000-08-08 | 13 14 |  |  | 0d |  | COST; OP [160 h]; Carpenters [160 h]; LB [160 h] | 70,000 | 14 15 |
| 14 23 | EXCAVATE FOR OFFICE BUILDING | 3d | 2000-07-26 | 2000-07-28 | 13 14 |  |  | 30d | 0d | COST; OP [120 h] | 27,000 | 14 23 |
| 23 24 | SPREAD FOOTINGS OFFICE | 4d | 2000-07-31 | 2000-08-03 | 14 23 |  |  | 30d | 0d | COST; Carpenters [128 h]; LB [64 h] | 17,500 | 23 24 |
| 24 25 | FORM AND POUR GRADE BEAMS OFFICE | 6d | 2000-08-04 | 2000-08-11 | 23 24 |  |  | 30d | 0d | COST; Carpenters [192 h]; LB [96 h] | 21,000 | 24 25 |
| 15 16 | EXCAVATE PLANT WAREHOUSE | 5d | 2000-08-09 | 2000-08-15 | 14 15 |  |  | 0d |  | COST; OP [200 h] | 86,000 | 15 16 |
| 25 26 | BACKFILL AND COMPACT OFFICE | 1d | 2000-08-14 | 2000-08-14 | 24 25 |  |  | 30d | 0d | COST; OP [40 h] | 1,800 | 25 26 |
| 26 27 | UNDERSLAB PLUMBING OFFICE | 3d | 2000-08-15 | 2000-08-17 | 25 26 |  |  | 30d | 0d | COST; Plumbers [96 h] | 9,000 | 26 27 |
| 16 17 | POUR PILE CAPS P-W | 5d | 2000-08-16 | 2000-08-22 | 15 16 |  |  | 0d |  | COST; Carpenters [160 h]; LB [800 h] | 50,000 | 16 17 |
| 27 28 | UNDERSLAB CONDUIT OFFICE | 3d | 2000-08-18 | 2000-08-22 | 26 27 |  |  | 30d | 0d | COST; Carpenters [96 h]; LB [48 h] | 5,000 | 27 28 |
| 17 18 | FORM AND POUR GRADE BEAMS P-W | 10d | 2000-08-23 | 2000-09-06 | 16 17 |  |  | 0d |  | COST; Carpenters [160 h]; LB [160 h] | 70,000 | 17 18 |
| 28 29 | FORM AND POUR SLABS OFFICE | 3d | 2000-08-23 | 2000-08-25 | 27 28 |  |  | 30d |  | COST; Carpenters [96 h]; LB [48 h] | 18,000 | 28 99 |
| 18 19 | BACKFILL AND COMPACT P-W | 3d | 2000-09-07 | 2000-09-11 | 17 18 |  |  | 0d |  | COST; OP [120 h] | 9,000 | 18 19 |
| 18 21 | FORM AND POUR RAILROAD LOADING DOCK P-W | 5d | 2000-09-07 | 2000-09-13 | 17 18 |  |  | 8d | 0d | COST; Carpenters [160 h]; LB [80 h] | 15,000 | 18 21 |
| 18 22 | FORM AND POUR TRUCK LOADING DOCK P-W | 5d | 2000-09-07 | 2000-09-13 | 17 18 |  |  | 8d |  | COST; Carpenters [160 h]; LB [80 h] | 15,000 | 18 22 |
| 19 20 | UNDERSLAB PLUMBING P-W | 5d | 2000-09-12 | 2000-09-18 | 18 19 |  |  | 0d |  | COST; Plumbers [160 h] | 12,000 | 19 20 |
| 21 22 | 21 22 | 0d | 2000-09-14 | 2000-09-13 | 18 21 | 2000-09-14 | 2000-09-14 | 8d |  |  |  | 21 22 |
| 20 22 | UNDERSLAB CONDUIT P-W | 5d | 2000-09-19 | 2000-09-25 | 19 20 |  |  | 0d |  | COST; Electricians [240 h] | 7,500 | 20 22 |
| 22 29 | FORM AND POUR SLABS P-W | 10d | 2000-09-26 | 2000-10-09 | 18 22, 20 22, 21 22 |  |  | 0d |  | COST; Carpenters [320 h]; LB [160 h] | 225,000 | 22 29 |
| 29 30 | ERECT STRUCTURAL STEEL P-W | 10d | 2000-10-10 | 2000-10-23 | 22 29, 28 29 |  |  | 0d |  | COST; OP [160 h]; Iron Workers [480 h] | 50,000 | 29 30 |
| 30 31 | PLUMB AND BOLT STEEL P-W | 5d | 2000-10-24 | 2000-10-30 | 29 30 |  |  | 0d |  | COST; OP [80 h]; Iron Workers [240 h] | 15,000 | 30 31 |
| 31 32 | ERECT CRANEWAY AND CRANE P-W | 5d | 2000-10-31 | 2000-11-06 | 30 31 |  |  | 0d |  | COST; Iron Workers [160 h] | 20,000 | 31 32 |
| 31 33 | ERECT MONORAIL TRACK P-W | 3d | 2000-10-31 | 2000-11-02 | 30 31 |  |  | 2d |  | COST; Iron Workers [96 h] | 10,000 | 31 33 |
| 32 33 | 32 33 | 0d | 2000-11-07 | 2000-11-06 | 31 32 | 2000-11-07 | 2000-11-07 | 0d |  |  |  | 32 33 |
| 33 34 | ERECT BAR JOISTS P-W | 3d | 2000-11-07 | 2000-11-09 | 31 33, 32 33 |  |  | 0d |  | COST; OP [48 h]; Iron Workers [144 h] | 15,000 | 33 34 |
| 34 35 | ERECT ROOF PLANKS P-W | 3d | 2000-11-10 | 2000-11-14 | 33 34 |  |  | 0d |  | COST; LB [48 h]; OP [48 h]; Carpenters [48 h] | 15,000 | 34 35 |
| 35 36 | ERECT SIDING P-W | 10d | 2000-11-15 | 2000-11-29 | 34 35 |  |  | 0d |  | COST; OP [160 h]; Iron Workers [480 h] | 75,000 | 35 36 |
| 35 37 | BUILT-UP ROOFING P-W | 5d | 2000-11-15 | 2000-11-21 | 34 35 |  |  | 5d |  | COST; Roofers [320 h] | 175,000 | 35 37 |
| 80 | END OF NETWORK | 1d | 2000-11-30 | 2000-11-30 | 35 37, 36 37 |  |  | 0d |  |  |  |  |
| 36 37 | 36 37 | 0d | 2000-11-30 | 2000-11-29 | 35 36 | 2000-11-30 | 2000-11-30 | 0d |  |  |  | 36 37 |
